# HABILITACIÓN DE ACCESOS Y PLATAFORMAS Y MOVIMIENTO DE TIERRAS II PARTE - CUENCA HUAURA

Schedule from Primavera P6, 2023-02-01 to 2023-12-28, data date 2023-02-01.

## Calendars

- Calendario ARCC turno unico: Mon-Sun 07:00-17:00.

## Schedule

| ID | WBS | Activity | Type | Duration | Start | Finish | Predecessors | Total float | Free float |
| --- | --- | --- | --- | --- | --- | --- | --- | --- | --- |
| 406 |  | Fin | milestone | 0d | 2023-12-28 | 2023-12-28 | 09, 10, 13, 17, 6, 7, 379, 386, 389, 399, 403, 404 | 0d |  |
|  | 1 | **HITOS DEL PROYECTO** |  |  | 2023-02-01 | 2023-12-28 |  |  |  |
| 2 |  | Hito 1: Inicio de obra - Acceso al Sitio | milestone | 0d | 2023-02-01 | 2023-02-01 |  | 0d |  |
| 3 |  | Hito 2: Inicio de Habilitación y Mejoramiento de accesos | milestone | 0d | 2023-02-16 | 2023-02-16 | 2 FS+15d | 0d |  |
| 4 |  | Hito 3: Inicio de Movimiento de Tierras - Dique Paquete 2 | milestone | 0d | 2023-03-03 | 2023-03-03 | 3 FS+15d | 28d | 0d |
| 6 |  | Hito 5: Inicio de Movimiento de Tierras - Dique Paquete 3 | milestone | 0d | 2023-05-17 | 2023-05-17 | 3 FS+90d | 0d |  |
| 5 |  | Hito 4: Culminación de Diques Paquete 2 | milestone | 0d | 2023-08-30 | 2023-08-30 | 4 FS+180d, 26, 27, 31, 33, 46, 47, 48, 49, 50, 51, 52, 53, 60, 61, 65, 68, 81, 82, 83, 84, 85, 86, 87, 88, 95, 96, 97, 101, 104, 116, 117, 118, 119, 120, 121, 122, 123, 131, 132, 133, 137, 139, 140, 153, 154, 155, 156, 157, 158, 159, 160, 166, 167, 168, 169 | 120d |  |
| 7 |  | Hito 6: Culminación de Diques Paquete 3 | milestone | 0d | 2023-12-28 | 2023-12-28 | 6 FS+225d, 176, 177, 181, 194, 195, 196, 197, 198, 199, 206, 207, 211, 224, 225, 226, 227, 228, 229, 236, 237, 241, 254, 255, 256, 257, 258, 259, 266, 267, 271, 284, 285, 286, 287, 288, 289, 296, 297, 298, 302, 304, 316, 317, 318, 319, 320, 321, 328, 329, 333, 346, 347, 348, 349, 350, 351 | 0d |  |
|  | 2 | **OBRAS PROVISIONALES** |  |  | 2023-02-01 | 2023-12-27 |  |  |  |
| 09 |  | Campamento Provisional de Obra | resource dependent | 30d | 2023-02-01 | 2023-03-02 | 2 | 300d |  |
| 10 |  | Movilización y Desmovilización de maquinaria pesada | resource dependent | 330d | 2023-02-01 | 2023-12-27 | 2 | 0d |  |
| 12 |  | Limpieza manual de material vegetal y de residuos | resource dependent | 15d | 2023-02-16 | 2023-03-02 | 3 | 0d |  |
| 11 |  | Mejoramiento y Habilitación de caminos de acceso | resource dependent | 35d | 2023-03-03 | 2023-04-06 | 12 | 0d |  |
| 14 |  | Tubería HDPE Corrugada Ø=630mm, para caminos de acceso (o similar) | resource dependent | 10d | 2023-04-07 | 2023-04-16 | 11 | 0d |  |
| 15 |  | Tubería HDPE Corrugada Ø=1000mm, para caminos de acceso (o similar) | resource dependent | 15d | 2023-04-17 | 2023-05-01 | 14 | 0d |  |
| 13 |  | Mantenimiento de caminos de acceso | resource dependent | 240d | 2023-05-02 | 2023-12-27 | 15 | 0d |  |
|  | 3 | **TOPOGRAFIA** |  |  | 2023-02-01 | 2023-12-27 |  |  |  |
| 17 |  | Trazo y replanteo durante la obra | resource dependent | 330d | 2023-02-01 | 2023-12-27 | 2 | 0d |  |
|  | 4 | **CONSTRUCCIÓN DE DIQUES** |  |  | 2023-03-03 | 2023-12-27 |  |  |  |
|  | 1 | **DIQUE DI-PR-13-D** |  |  | 2023-03-19 | 2023-08-09 |  |  |  |
|  | 1 | **Excavaciones** |  |  | 2023-03-19 | 2023-04-18 |  |  |  |
| 21 |  | Desbroce | resource dependent | 5d | 2023-03-19 | 2023-03-23 | 91 | 88d | 0d |
| 27 |  | Conformación de material excedente en DMO | resource dependent | 5d | 2023-03-19 | 2023-03-23 | 42 FS-5d, 43 FS-5d | 279d | 159d |
| 22 |  | Remoción de dique existente | resource dependent | 20d | 2023-03-24 | 2023-04-12 | 21 | 88d | 0d |
| 23 |  | Excavación de cimentación | resource dependent | 18d | 2023-03-31 | 2023-04-17 | 21, 22 FS-13d, 92 | 88d | 0d |
| 25 |  | Excavación de uña | resource dependent | 18d | 2023-03-31 | 2023-04-17 | 21, 22 FS-13d, 94 | 88d | 0d |
| 26 |  | Conformación de material excedente en DME | resource dependent | 18d | 2023-03-31 | 2023-04-17 | 44 FS-18d, 45 FS-18d | 254d | 134d |
| 24 |  | Perfilado y conformación de Plataforma de fundación | resource dependent | 18d | 2023-04-01 | 2023-04-18 | 23 FS-17d, 25 FS-17d, 93 | 88d | 0d |

Notes:
- 406: Expenses: Fin - (cost) 0
- 2: Expenses: Hito 1: Inicio de obra - Acceso al Sitio - (cost) 0
- 3: Expenses: Hito 2: Inicio de Habilitación y Mejoramiento de accesos - (cost) 0
- 4: Expenses: Hito 3: Inicio de Movimiento de Tierras - Dique Paquete 2 - (cost) 0
- 6: Expenses: Hito 5: Inicio de Movimiento de Tierras - Dique Paquete 3 - (cost) 0
- 5: Expenses: Hito 4: Culminación de Diques Paquete 2 - (cost) 0
- 7: Expenses: Hito 6: Culminación de Diques Paquete 3 - (cost) 0

| ID | WBS | Activity | Type | Duration | Start | Finish | Predecessors | Total float | Free float |
| --- | --- | --- | --- | --- | --- | --- | --- | --- | --- |
|  | 2 | **Rellenos** |  |  | 2023-04-10 | 2023-08-09 |  |  |  |
| 29 |  | Relleno con material granular (incluye extracción de material, zarandeo y combinación de material) | resource dependent | 39d | 2023-04-10 | 2023-05-18 | 24 FS-9d, 099 | 88d | 0d |
| 32 |  | Perfilado de Talud del dique | resource dependent | 39d | 2023-04-11 | 2023-05-19 | 29 FS-38d, 102 | 88d | 0d |
| 30 |  | Relleno sin compactar | resource dependent | 12d | 2023-07-22 | 2023-08-02 | 38, 39 | 140d | 0d |
| 33 |  | Grava para Drenaje | resource dependent | 7d | 2023-07-22 | 2023-07-28 | 38, 39 | 152d | 0d |
| 31 |  | Relleno afirmado | resource dependent | 7d | 2023-08-03 | 2023-08-09 | 30 | 140d | 0d |
|  | 3 | **Geotextil** |  |  | 2023-05-13 | 2023-07-20 |  |  |  |
| 36 |  | Zanja de anclaje | resource dependent | 68d | 2023-05-13 | 2023-07-19 | 32 FS-7d, 107 | 88d | 0d |
| 35 |  | Instalación de Geotextil 400 gr/m2 | resource dependent | 68d | 2023-05-14 | 2023-07-20 | 36 FS-67d | 88d | 0d |
|  | 4 | **Colocación de roca** |  |  | 2023-03-29 | 2023-07-21 |  |  |  |
| 40 |  | Extracción y Selección de Rocas Reutilizables (50% de roca utilizable) | resource dependent | 58d | 2023-03-29 | 2023-05-25 | 22 FS-15d | 88d | 0d |
| 38 |  | Colocación de roca en uña | resource dependent | 68d | 2023-05-15 | 2023-07-21 | 35 FS-67d, 40 FS-11d | 88d | 0d |
| 39 |  | Colocación de roca en Talud | resource dependent | 68d | 2023-05-15 | 2023-07-21 | 35 FS-67d, 40 FS-11d | 88d | 0d |
|  | 5 | **Transportes** |  |  | 2023-03-19 | 2023-08-09 |  |  |  |
| 42 |  | Transporte de material orgánico (a DMO) D<=1km | resource dependent | 5d | 2023-03-19 | 2023-03-23 | 21 SS | 279d | 0d |
| 43 |  | Transporte de material orgánico (a DMO) D>1km | resource dependent | 5d | 2023-03-19 | 2023-03-23 | 21 SS | 279d | 0d |
| 44 |  | Transporte de material excedente (dique provisional) D<=1km | resource dependent | 18d | 2023-03-31 | 2023-04-17 | 23 SS, 25 SS | 254d | 0d |
| 45 |  | Transporte de material excedente (dique provisional) D> 1km | resource dependent | 18d | 2023-03-31 | 2023-04-17 | 23 SS, 25 SS | 254d | 0d |
| 50 |  | Transporte de material de préstamo cantera de rio (cuerpo de terraplén) D<=1km | resource dependent | 39d | 2023-04-10 | 2023-05-18 | 29 SS | 223d | 103d |
| 51 |  | Transporte de material de préstamo cantera de rio (cuerpo de terraplén) D>1km | resource dependent | 39d | 2023-04-10 | 2023-05-18 | 29 SS | 223d | 103d |
| 48 |  | Transporte de roca D<=1km | resource dependent | 68d | 2023-05-15 | 2023-07-21 | 38 SS, 39 SS | 159d | 39d |
| 49 |  | Transporte de roca D>1km | resource dependent | 68d | 2023-05-15 | 2023-07-21 | 38 SS, 39 SS | 159d | 39d |
| 52 |  | Transporte de material seleccionado para zanja D<=1km | resource dependent | 7d | 2023-07-22 | 2023-07-28 | 33 SS | 152d | 32d |
| 53 |  | Transporte de material seleccionado para zanja D>1km | resource dependent | 7d | 2023-07-22 | 2023-07-28 | 33 SS | 152d | 32d |
| 46 |  | Transporte de material de préstamo (afirmado) D<=1km | resource dependent | 7d | 2023-08-03 | 2023-08-09 | 31 SS | 140d | 20d |
| 47 |  | Transporte de material de préstamo (afirmado) D>1km | resource dependent | 7d | 2023-08-03 | 2023-08-09 | 31 SS | 140d | 20d |

| ID | WBS | Activity | Type | Duration | Start | Finish | Predecessors | Total float | Free float |
| --- | --- | --- | --- | --- | --- | --- | --- | --- | --- |
|  | 10 | **DIQUE DI-PR-19A-D** |  |  | 2023-06-20 | 2023-12-27 |  |  |  |
|  | 1 | **Excavaciones** |  |  | 2023-06-20 | 2023-09-12 |  |  |  |
| 292 |  | Desbroce | resource dependent | 15d | 2023-06-20 | 2023-07-04 | 324 | 0d |  |
| 297 |  | Conformación de material excedente en DMO | resource dependent | 19d | 2023-06-20 | 2023-07-08 | 312 FS-15d, 313 FS-15d | 172d |  |
| 293 |  | Excavación de cimentación | resource dependent | 62d | 2023-07-05 | 2023-09-04 | 292 | 0d |  |
| 295 |  | Excavación de uña | resource dependent | 62d | 2023-07-05 | 2023-09-04 | 292 | 0d |  |
| 296 |  | Conformación de material excedente en DME | resource dependent | 62d | 2023-07-05 | 2023-09-04 | 314 FS-62d, 315 FS-62d | 114d |  |
| 294 |  | Perfilado y conformación de Plataforma de fundación | resource dependent | 68d | 2023-07-07 | 2023-09-12 | 293 FS-60d, 295 FS-60d | 0d |  |
| 298 |  | Excavación Localizada - Sobreexcavación | resource dependent | 7d | 2023-09-05 | 2023-09-11 | 293, 295 | 107d |  |
|  | 2 | **Rellenos** |  |  | 2023-07-14 | 2023-12-27 |  |  |  |
| 300 |  | Relleno con material granular (incluye extracción de material, zarandeo y combinac | resource dependent | 80d | 2023-07-14 | 2023-10-01 | 294 FS-61d | 0d |  |
| 303 |  | Perfilado de Talud del dique | resource dependent | 80d | 2023-07-15 | 2023-10-02 | 300 FS-79d | 0d |  |
| 301 |  | Relleno sin compactar | resource dependent | 38d | 2023-11-04 | 2023-12-11 | 309 FS-24d, 310 FS-24d | 0d |  |
| 304 |  | Relleno con material seleccionado (incluye extracción de material, zarandeo y combinación de material) en sobreexcavación | resource dependent | 37d | 2023-11-04 | 2023-12-10 | 309 FS-24d, 310 FS-24d | 17d |  |
| 302 |  | Relleno afirmado | resource dependent | 16d | 2023-12-12 | 2023-12-27 | 301 | 0d |  |
|  | 3 | **Geotextil** |  |  | 2023-07-22 | 2023-11-26 |  |  |  |
| 307 |  | Zanja de anclaje | resource dependent | 127d | 2023-07-22 | 2023-11-25 | 303 FS-73d | 0d |  |
| 306 |  | Instalación de Geotextil 400 gr/m2 | resource dependent | 127d | 2023-07-23 | 2023-11-26 | 307 FS-126d | 0d |  |
|  | 4 | **Colocación de roca** |  |  | 2023-07-24 | 2023-11-27 |  |  |  |
| 309 |  | Colocación de roca en uña | resource dependent | 127d | 2023-07-24 | 2023-11-27 | 306 FS-126d | 0d |  |
| 310 |  | Colocación de roca en Talud | resource dependent | 127d | 2023-07-24 | 2023-11-27 | 306 FS-126d | 0d |  |
|  | 5 | **Transportes** |  |  | 2023-06-20 | 2023-12-27 |  |  |  |
| 312 |  | Transporte de material orgánico (a DMO) D<=1km | resource dependent | 15d | 2023-06-20 | 2023-07-04 | 292 SS | 172d | 0d |
| 313 |  | Transporte de material orgánico (a DMO) D>1km | resource dependent | 15d | 2023-06-20 | 2023-07-04 | 292 SS | 172d | 0d |
| 314 |  | Transporte de material excedente (dique provisional) D<=1km | resource dependent | 62d | 2023-07-05 | 2023-09-04 | 293 SS, 295 SS | 114d | 0d |
| 315 |  | Transporte de material excedente (dique provisional) D> 1km | resource dependent | 62d | 2023-07-05 | 2023-09-04 | 293 SS, 295 SS | 114d | 0d |
| 320 |  | Transporte de material de préstamo cantera de rio (cuerpo de terraplén) D<=1km | resource dependent | 80d | 2023-07-14 | 2023-10-01 | 300 SS | 87d |  |
| 321 |  | Transporte de material de préstamo cantera de rio (cuerpo de terraplén) D>1km | resource dependent | 80d | 2023-07-14 | 2023-10-01 | 300 SS | 87d |  |
| 318 |  | Transporte de roca D<=1km | resource dependent | 127d | 2023-07-24 | 2023-11-27 | 309 SS, 310 SS | 30d |  |
| 319 |  | Transporte de roca D>1km | resource dependent | 127d | 2023-07-24 | 2023-11-27 | 309 SS, 310 SS | 30d |  |
| 316 |  | Transporte de material de préstamo (afirmado) D<=1km | resource dependent | 16d | 2023-12-12 | 2023-12-27 | 302 SS | 0d |  |
| 317 |  | Transporte de material de préstamo (afirmado) D>1km | resource dependent | 16d | 2023-12-12 | 2023-12-27 | 302 SS | 0d |  |

| ID | WBS | Activity | Type | Duration | Start | Finish | Predecessors | Total float | Free float |
| --- | --- | --- | --- | --- | --- | --- | --- | --- | --- |
|  | 11 | **DIQUE DI-PR-19B-D** |  |  | 2023-06-13 | 2023-12-27 |  |  |  |
|  | 1 | **Excavaciones** |  |  | 2023-06-13 | 2023-08-15 |  |  |  |
| 324 |  | Desbroce | resource dependent | 7d | 2023-06-13 | 2023-06-19 | 360 | 0d |  |
| 329 |  | Conformación de material excedente en DMO | resource dependent | 7d | 2023-06-13 | 2023-06-19 | 342 FS-7d, 343 FS-7d | 191d |  |
| 325 |  | Excavación de cimentación | resource dependent | 56d | 2023-06-20 | 2023-08-14 | 324 | 0d |  |
| 327 |  | Excavación de uña | resource dependent | 56d | 2023-06-20 | 2023-08-14 | 324 | 0d |  |
| 328 |  | Conformación de material excedente en DME | resource dependent | 56d | 2023-06-20 | 2023-08-14 | 344 FS-56d, 345 FS-56d | 135d |  |
| 326 |  | Perfilado y conformación de Plataforma de fundación | resource dependent | 55d | 2023-06-22 | 2023-08-15 | 325 FS-54d, 327 FS-54d | 0d |  |
|  | 2 | **Rellenos** |  |  | 2023-07-02 | 2023-12-27 |  |  |  |
| 331 |  | Relleno con material granular (incluye extracción de material, zarandeo y combinac | resource dependent | 49d | 2023-07-02 | 2023-08-19 | 326 FS-45d | 0d |  |
| 334 |  | Perfilado de Talud del dique | resource dependent | 49d | 2023-07-03 | 2023-08-20 | 331 FS-48d | 0d |  |
| 332 |  | Relleno sin compactar | resource dependent | 23d | 2023-11-28 | 2023-12-20 | 339 FS-21d, 340 FS-21d | 0d |  |
| 333 |  | Relleno afirmado | resource dependent | 7d | 2023-12-21 | 2023-12-27 | 332 | 0d |  |
|  | 3 | **Geotextil** |  |  | 2023-07-10 | 2023-12-17 |  |  |  |
| 337 |  | Zanja de anclaje | resource dependent | 160d | 2023-07-10 | 2023-12-16 | 334 FS-42d | 0d |  |
| 336 |  | Instalación de Geotextil 400 gr/m2 | resource dependent | 160d | 2023-07-11 | 2023-12-17 | 337 FS-159d | 0d |  |
|  | 4 | **Colocación de roca** |  |  | 2023-07-12 | 2023-12-18 |  |  |  |
| 339 |  | Colocación de roca en uña | resource dependent | 160d | 2023-07-12 | 2023-12-18 | 336 FS-159d | 0d |  |
| 340 |  | Colocación de roca en Talud | resource dependent | 160d | 2023-07-12 | 2023-12-18 | 336 FS-159d | 0d |  |
|  | 5 | **Transportes** |  |  | 2023-06-13 | 2023-12-27 |  |  |  |
| 342 |  | Transporte de material orgánico (a DMO) D<=1km | resource dependent | 7d | 2023-06-13 | 2023-06-19 | 324 SS | 191d | 0d |
| 343 |  | Transporte de material orgánico (a DMO) D>1km | resource dependent | 7d | 2023-06-13 | 2023-06-19 | 324 SS | 191d | 0d |
| 344 |  | Transporte de material excedente (dique provisional) D<=1km | resource dependent | 56d | 2023-06-20 | 2023-08-14 | 325 SS, 327 SS | 135d | 0d |
| 345 |  | Transporte de material excedente (dique provisional) D> 1km | resource dependent | 56d | 2023-06-20 | 2023-08-14 | 325 SS, 327 SS | 135d | 0d |
| 350 |  | Transporte de material de préstamo cantera de rio (cuerpo de terraplén) D<=1km | resource dependent | 49d | 2023-07-02 | 2023-08-19 | 331 SS | 130d |  |
| 351 |  | Transporte de material de préstamo cantera de rio (cuerpo de terraplén) D>1km | resource dependent | 49d | 2023-07-02 | 2023-08-19 | 331 SS | 130d |  |
| 348 |  | Transporte de roca D<=1km | resource dependent | 160d | 2023-07-12 | 2023-12-18 | 339 SS, 340 SS | 9d |  |
| 349 |  | Transporte de roca D>1km | resource dependent | 160d | 2023-07-12 | 2023-12-18 | 339 SS, 340 SS | 9d |  |
| 346 |  | Transporte de material de préstamo (afirmado) D<=1km | resource dependent | 7d | 2023-12-21 | 2023-12-27 | 333 SS | 0d |  |
| 347 |  | Transporte de material de préstamo (afirmado) D>1km | resource dependent | 7d | 2023-12-21 | 2023-12-27 | 333 SS | 0d |  |

| ID | WBS | Activity | Type | Duration | Start | Finish | Predecessors | Total float | Free float |
| --- | --- | --- | --- | --- | --- | --- | --- | --- | --- |
|  | 12 | **ACCESOS-1** |  |  | 2023-05-17 | 2023-06-12 |  |  |  |
|  | 1 | **Excavaciones** |  |  | 2023-05-17 | 2023-05-26 |  |  |  |
| 354 |  | Desbroce | resource dependent | 5d | 2023-05-17 | 2023-05-21 | 6 | 0d |  |
| 357 |  | Conformación de material excedente en DMO | resource dependent | 5d | 2023-05-17 | 2023-05-21 | 362 FS-5d, 363 FS-5d | 220d |  |
| 355 |  | Excavación de cimentación | resource dependent | 5d | 2023-05-22 | 2023-05-26 | 354 | 0d |  |
| 356 |  | Conformación de material excedente en DME | resource dependent | 5d | 2023-05-22 | 2023-05-26 | 364 FS-5d, 365 FS-5d | 215d |  |
|  | 2 | **Rellenos** |  |  | 2023-05-27 | 2023-06-12 |  |  |  |
| 359 |  | Relleno con material granular (incluye extracción de material, zarandeo y combinac | resource dependent | 10d | 2023-05-27 | 2023-06-05 | 355 | 0d |  |
| 360 |  | Relleno afirmado | resource dependent | 7d | 2023-06-06 | 2023-06-12 | 359 | 0d |  |
|  | 3 | **Transportes** |  |  | 2023-05-17 | 2023-06-12 |  |  |  |
| 362 |  | Transporte de material orgánico (a DMO) D<=1km | resource dependent | 5d | 2023-05-17 | 2023-05-21 | 354 SS | 220d | 0d |
| 363 |  | Transporte de material orgánico (a DMO) D>1km | resource dependent | 5d | 2023-05-17 | 2023-05-21 | 354 SS | 220d | 0d |
| 364 |  | Transporte de material excedente (dique provisional) D<=1km | resource dependent | 5d | 2023-05-22 | 2023-05-26 | 355 SS | 215d | 0d |
| 365 |  | Transporte de material excedente (dique provisional) D> 1km | resource dependent | 5d | 2023-05-22 | 2023-05-26 | 355 SS | 215d | 0d |
| 368 |  | Transporte de material de préstamo cantera de rio (cuerpo de terraplén) D<=1km | resource dependent | 10d | 2023-05-27 | 2023-06-05 | 359 SS | 205d |  |
| 369 |  | Transporte de material de préstamo cantera de rio (cuerpo de terraplén) D>1km | resource dependent | 10d | 2023-05-27 | 2023-06-05 | 359 SS | 205d |  |
| 366 |  | Transporte de material de préstamo (afirmado) D<=1km | resource dependent | 7d | 2023-06-06 | 2023-06-12 | 360 SS | 198d |  |
| 367 |  | Transporte de material de préstamo (afirmado) D>1km | resource dependent | 7d | 2023-06-06 | 2023-06-12 | 360 SS | 198d |  |
|  | 2 | **DIQUE DI-PR-25-I** |  |  | 2023-03-09 | 2023-04-18 |  |  |  |
|  | 1 | **Excavaciones** |  |  | 2023-03-09 | 2023-03-21 |  |  |  |
| 56 |  | Desbroce | resource dependent | 5d | 2023-03-09 | 2023-03-13 | 164 | 88d | 0d |
| 61 |  | Conformación de material excedente en DMO | resource dependent | 5d | 2023-03-09 | 2023-03-13 | 77 FS-5d, 78 FS-5d | 289d | 169d |
| 57 |  | Excavación de cimentación | resource dependent | 5d | 2023-03-14 | 2023-03-18 | 56 | 88d | 0d |
| 59 |  | Excavación de uña | resource dependent | 5d | 2023-03-14 | 2023-03-18 | 56 | 88d | 0d |
| 60 |  | Conformación de material excedente en DME | resource dependent | 5d | 2023-03-14 | 2023-03-18 | 79 FS-5d, 80 FS-5d | 284d | 164d |
| 58 |  | Perfilado y conformación de Plataforma de fundación | resource dependent | 4d | 2023-03-16 | 2023-03-19 | 57 FS-3d, 59 FS-3d, 62 FS-6d | 88d | 0d |
| 62 |  | Excavación Localizada - Sobreexcavación | resource dependent | 3d | 2023-03-19 | 2023-03-21 | 57, 59 | 88d | 0d |

| ID | WBS | Activity | Type | Duration | Start | Finish | Predecessors | Total float | Free float |
| --- | --- | --- | --- | --- | --- | --- | --- | --- | --- |
|  | 2 | **Rellenos** |  |  | 2023-03-20 | 2023-04-18 |  |  |  |
| 64 |  | Relleno con material granular (incluye extracción de material, zarandeo y combinac | resource dependent | 7d | 2023-03-20 | 2023-03-26 | 58 | 88d | 0d |
| 67 |  | Perfilado de Talud del dique | resource dependent | 7d | 2023-03-21 | 2023-03-27 | 64 FS-6d | 88d | 0d |
| 68 |  | Relleno con material seleccionado (incluye extracción de material, zarandeo y combinación de material) en sobreexcavación | resource dependent | 3d | 2023-03-27 | 2023-03-29 | 64 | 273d | 153d |
| 65 |  | Relleno sin compactar | resource dependent | 3d | 2023-04-11 | 2023-04-13 | 74, 75 | 253d | 0d |
| 69 |  | Grava para Drenaje | resource dependent | 3d | 2023-04-11 | 2023-04-13 | 74, 75 | 253d | 0d |
| 66 |  | Relleno afirmado | resource dependent | 5d | 2023-04-14 | 2023-04-18 | 65, 69 | 253d | 0d |
|  | 3 | **Geotextil** |  |  | 2023-03-28 | 2023-04-09 |  |  |  |
| 72 |  | Zanja de anclaje | resource dependent | 12d | 2023-03-28 | 2023-04-08 | 67 | 88d | 0d |
| 71 |  | Instalación de Geotextil 400 gr/m2 | resource dependent | 12d | 2023-03-29 | 2023-04-09 | 72 FS-11d | 215d | 0d |
|  | 4 | **Colocación de roca** |  |  | 2023-03-30 | 2023-04-10 |  |  |  |
| 74 |  | Colocación de roca en uña | resource dependent | 12d | 2023-03-30 | 2023-04-10 | 71 FS-11d | 215d | 0d |
| 75 |  | Colocación de roca en Talud | resource dependent | 12d | 2023-03-30 | 2023-04-10 | 71 FS-11d | 215d | 0d |
|  | 5 | **Transportes** |  |  | 2023-03-09 | 2023-04-18 |  |  |  |
| 77 |  | Transporte de material orgánico (a DMO) D<=1km | resource dependent | 5d | 2023-03-09 | 2023-03-13 | 56 SS | 289d | 0d |
| 78 |  | Transporte de material orgánico (a DMO) D>1km | resource dependent | 5d | 2023-03-09 | 2023-03-13 | 56 SS | 289d | 0d |
| 79 |  | Transporte de material excedente (dique provisional) D<=1km | resource dependent | 5d | 2023-03-14 | 2023-03-18 | 57 SS, 59 SS | 284d | 0d |
| 80 |  | Transporte de material excedente (dique provisional) D> 1km | resource dependent | 5d | 2023-03-14 | 2023-03-18 | 57 SS, 59 SS | 284d | 0d |
| 85 |  | Transporte de material de préstamo cantera de rio (cuerpo de terraplén) D<=1km | resource dependent | 7d | 2023-03-20 | 2023-03-26 | 64 SS | 276d | 156d |
| 86 |  | Transporte de material de préstamo cantera de rio (cuerpo de terraplén) D>1km | resource dependent | 7d | 2023-03-20 | 2023-03-26 | 64 SS | 276d | 156d |
| 83 |  | Transporte de roca D<=1km | resource dependent | 12d | 2023-03-30 | 2023-04-10 | 74 SS, 75 SS | 261d | 141d |
| 84 |  | Transporte de roca D>1km | resource dependent | 12d | 2023-03-30 | 2023-04-10 | 74 SS, 75 SS | 261d | 141d |
| 87 |  | Transporte de material seleccionado para zanja D<=1km | resource dependent | 3d | 2023-04-11 | 2023-04-13 | 69 SS | 258d | 138d |
| 88 |  | Transporte de material seleccionado para zanja D>1km | resource dependent | 3d | 2023-04-11 | 2023-04-13 | 69 SS | 258d | 138d |
| 81 |  | Transporte de material de préstamo (afirmado) D<=1km | resource dependent | 5d | 2023-04-14 | 2023-04-18 | 66 SS | 253d | 133d |
| 82 |  | Transporte de material de préstamo (afirmado) D>1km | resource dependent | 5d | 2023-04-14 | 2023-04-18 | 66 SS | 253d | 133d |

| ID | WBS | Activity | Type | Duration | Start | Finish | Predecessors | Total float | Free float |
| --- | --- | --- | --- | --- | --- | --- | --- | --- | --- |
|  | 3 | **DIQUE DI-PR-24-D** |  |  | 2023-03-14 | 2023-05-26 |  |  |  |
|  | 1 | **Excavaciones** |  |  | 2023-03-14 | 2023-03-30 |  |  |  |
| 91 |  | Desbroce | resource dependent | 5d | 2023-03-14 | 2023-03-18 | 56 | 88d | 0d |
| 96 |  | Conformación de material excedente en DMO | resource dependent | 5d | 2023-03-14 | 2023-03-18 | 112 FS-5d, 113 FS-5d | 284d | 164d |
| 92 |  | Excavación de cimentación | resource dependent | 12d | 2023-03-19 | 2023-03-30 | 57, 91 | 88d | 0d |
| 94 |  | Excavación de uña | resource dependent | 12d | 2023-03-19 | 2023-03-30 | 59, 91 | 88d | 0d |
| 95 |  | Conformación de material excedente en DME | resource dependent | 12d | 2023-03-19 | 2023-03-30 | 114 FS-12d, 115 FS-12d | 272d | 152d |
| 93 |  | Perfilado y conformación de Plataforma de fundación | resource dependent | 11d | 2023-03-20 | 2023-03-30 | 92 FS-11d, 94 FS-11d | 88d | 0d |
| 97 |  | Excavación Localizada - Sobreexcavación | resource dependent | 3d | 2023-03-28 | 2023-03-30 | 92 FS-3d, 94 FS-3d | 272d | 152d |
|  | 2 | **Rellenos** |  |  | 2023-03-27 | 2023-05-26 |  |  |  |
| 099 |  | Relleno con material granular (incluye extracción de material, zarandeo y combinación | resource dependent | 14d | 2023-03-27 | 2023-04-09 | 93 FS-4d, 64 | 88d | 0d |
| 102 |  | Perfilado de Talud del dique | resource dependent | 14d | 2023-03-28 | 2023-04-10 | 099 FS-13d, 67 | 88d | 0d |
| 103 |  | Relleno con material seleccionado (incluye extracción de material, zarandeo y combinación de material) en sobreexcavación | resource dependent | 5d | 2023-04-10 | 2023-04-14 | 099 | 257d |  |
| 100 |  | Relleno sin compactar | resource dependent | 7d | 2023-05-15 | 2023-05-21 | 109, 110 | 215d | 0d |
| 104 |  | Grava para Drenaje | resource dependent | 5d | 2023-05-15 | 2023-05-19 | 109, 110 | 222d | 0d |
| 101 |  | Relleno afirmado | resource dependent | 5d | 2023-05-22 | 2023-05-26 | 100 | 215d | 0d |
|  | 3 | **Geotextil** |  |  | 2023-04-09 | 2023-05-13 |  |  |  |
| 107 |  | Zanja de anclaje | resource dependent | 34d | 2023-04-09 | 2023-05-12 | 102 FS-2d, 72 | 88d | 0d |
| 106 |  | Instalación de Geotextil 400 gr/m2 | resource dependent | 34d | 2023-04-10 | 2023-05-13 | 107 FS-33d, 71 | 215d | 0d |
|  | 4 | **Colocación de roca** |  |  | 2023-04-11 | 2023-05-14 |  |  |  |
| 109 |  | Colocación de roca en uña | resource dependent | 34d | 2023-04-11 | 2023-05-14 | 106 FS-33d, 74 | 215d | 0d |
| 110 |  | Colocación de roca en Talud | resource dependent | 34d | 2023-04-11 | 2023-05-14 | 106 FS-33d, 75 | 215d | 0d |
|  | 5 | **Transportes** |  |  | 2023-03-14 | 2023-05-26 |  |  |  |
| 112 |  | Transporte de material orgánico (a DMO) D<=1km | resource dependent | 5d | 2023-03-14 | 2023-03-18 | 91 SS | 284d | 0d |
| 113 |  | Transporte de material orgánico (a DMO) D>1km | resource dependent | 5d | 2023-03-14 | 2023-03-18 | 91 SS | 284d | 0d |
| 114 |  | Transporte de material excedente (dique provisional) D<=1km | resource dependent | 12d | 2023-03-19 | 2023-03-30 | 92 SS, 94 SS | 272d | 0d |
| 115 |  | Transporte de material excedente (dique provisional) D> 1km | resource dependent | 12d | 2023-03-19 | 2023-03-30 | 92 SS, 94 SS | 272d | 0d |
| 120 |  | Transporte de material de préstamo cantera de rio (cuerpo de terraplén) D<=1km | resource dependent | 14d | 2023-03-27 | 2023-04-09 | 099 SS | 262d | 142d |
| 121 |  | Transporte de material de préstamo cantera de rio (cuerpo de terraplén) D>1km | resource dependent | 14d | 2023-03-27 | 2023-04-09 | 099 SS | 262d | 142d |
| 118 |  | Transporte de roca D<=1km | resource dependent | 34d | 2023-04-11 | 2023-05-14 | 109 SS, 110 SS | 227d | 107d |
| 119 |  | Transporte de roca D>1km | resource dependent | 34d | 2023-04-11 | 2023-05-14 | 109 SS, 110 SS | 227d | 107d |
| 122 |  | Transporte de material seleccionado para zanja D<=1km | resource dependent | 5d | 2023-05-15 | 2023-05-19 | 104 SS | 222d | 102d |
| 123 |  | Transporte de material seleccionado para zanja D>1km | resource dependent | 5d | 2023-05-15 | 2023-05-19 | 104 SS | 222d | 102d |
| 116 |  | Transporte de material de préstamo (afirmado) D<=1km | resource dependent | 5d | 2023-05-22 | 2023-05-26 | 101 SS | 215d | 95d |
| 117 |  | Transporte de material de préstamo (afirmado) D>1km | resource dependent | 5d | 2023-05-22 | 2023-05-26 | 101 SS | 215d | 95d |

| ID | WBS | Activity | Type | Duration | Start | Finish | Predecessors | Total float | Free float |
| --- | --- | --- | --- | --- | --- | --- | --- | --- | --- |
|  | 4 | **DIQUE DI-PR-12-I** |  |  | 2023-03-09 | 2023-08-29 |  |  |  |
|  | 1 | **Excavaciones** |  |  | 2023-03-09 | 2023-05-23 |  |  |  |
| 126 |  | Desbroce | resource dependent | 7d | 2023-03-09 | 2023-03-15 | 164 | 28d | 0d |
| 132 |  | Conformación de material excedente en DMO | resource dependent | 7d | 2023-03-09 | 2023-03-15 | 149 FS-7d, 150 FS-7d | 287d | 167d |
| 127 |  | Remoción de dique existente | resource dependent | 30d | 2023-03-16 | 2023-04-14 | 126 | 28d | 0d |
| 128 |  | Excavación de cimentación | resource dependent | 55d | 2023-03-23 | 2023-05-16 | 126, 127 FS-23d | 28d | 0d |
| 130 |  | Excavación de uña | resource dependent | 55d | 2023-03-23 | 2023-05-16 | 126, 127 FS-23d | 28d | 0d |
| 131 |  | Conformación de material excedente en DME | resource dependent | 62d | 2023-03-23 | 2023-05-23 | 151 FS-62d, 152 FS-62d | 218d | 98d |
| 129 |  | Perfilado y conformación de Plataforma de fundación | resource dependent | 54d | 2023-03-25 | 2023-05-17 | 128 FS-53d, 130 FS-53d | 28d | 0d |
| 133 |  | Excavación Localizada - Sobreexcavación | resource dependent | 7d | 2023-05-17 | 2023-05-23 | 128, 130 | 218d | 98d |
|  | 2 | **Rellenos** |  |  | 2023-04-01 | 2023-08-29 |  |  |  |
| 135 |  | Relleno con material granular (incluye extracción de material, zarandeo y combinación | resource dependent | 91d | 2023-04-01 | 2023-06-30 | 129 FS-47d | 28d | 0d |
| 138 |  | Perfilado de Talud del dique | resource dependent | 91d | 2023-04-02 | 2023-07-01 | 135 FS-90d | 28d | 0d |
| 139 |  | Relleno con material seleccionado (incluye extracción de material, zarandeo y combinación de material) en sobreexcavación | resource dependent | 35d | 2023-07-01 | 2023-08-04 | 135 | 145d | 25d |
| 136 |  | Relleno sin compactar | resource dependent | 31d | 2023-07-15 | 2023-08-14 | 145 FS-23d, 146 FS-23d | 120d | 0d |
| 140 |  | Grava para Drenaje | resource dependent | 10d | 2023-07-31 | 2023-08-09 | 145 FS-7d, 146 FS-7d | 140d | 0d |
| 137 |  | Relleno afirmado | resource dependent | 15d | 2023-08-15 | 2023-08-29 | 136 | 120d | 0d |
|  | 3 | **Geotextil** |  |  | 2023-04-17 | 2023-08-05 |  |  |  |
| 143 |  | Zanja de anclaje | resource dependent | 110d | 2023-04-17 | 2023-08-04 | 138 FS-76d | 28d | 0d |
| 142 |  | Instalación de Geotextil 400 gr/m2 | resource dependent | 110d | 2023-04-18 | 2023-08-05 | 143 FS-109d | 28d | 0d |
|  | 4 | **Colocación de roca** |  |  | 2023-03-21 | 2023-08-06 |  |  |  |
| 147 |  | Extracción y Selección de Rocas Reutilizables (50% de roca utilizable) | resource dependent | 60d | 2023-03-21 | 2023-05-19 | 127 FS-25d | 28d | 0d |
| 145 |  | Colocación de roca en uña | resource dependent | 110d | 2023-04-19 | 2023-08-06 | 142 FS-109d, 147 FS-31d | 28d | 0d |
| 146 |  | Colocación de roca en Talud | resource dependent | 110d | 2023-04-19 | 2023-08-06 | 142 FS-109d, 147 FS-31d | 28d | 0d |

| ID | WBS | Activity | Type | Duration | Start | Finish | Predecessors | Total float | Free float |
| --- | --- | --- | --- | --- | --- | --- | --- | --- | --- |
|  | 5 | **Transportes** |  |  | 2023-03-09 | 2023-08-29 |  |  |  |
| 149 |  | Transporte de material orgánico (a DMO) D<=1km | resource dependent | 7d | 2023-03-09 | 2023-03-15 | 126 SS | 287d | 0d |
| 150 |  | Transporte de material orgánico (a DMO) D>1km | resource dependent | 7d | 2023-03-09 | 2023-03-15 | 126 SS | 287d | 0d |
| 151 |  | Transporte de material excedente (dique provisional) D<=1km | resource dependent | 62d | 2023-03-23 | 2023-05-23 | 128 SS, 130 SS | 218d | 0d |
| 152 |  | Transporte de material excedente (dique provisional) D> 1km | resource dependent | 62d | 2023-03-23 | 2023-05-23 | 128 SS, 130 SS | 218d | 0d |
| 157 |  | Transporte de material de préstamo cantera de rio (cuerpo de terraplén) D<=1km | resource dependent | 91d | 2023-04-01 | 2023-06-30 | 135 SS | 180d | 60d |
| 158 |  | Transporte de material de préstamo cantera de rio (cuerpo de terraplén) D>1km | resource dependent | 91d | 2023-04-01 | 2023-06-30 | 135 SS | 180d | 60d |
| 155 |  | Transporte de roca D<=1km | resource dependent | 110d | 2023-04-19 | 2023-08-06 | 145 SS, 146 SS | 143d | 23d |
| 156 |  | Transporte de roca D>1km | resource dependent | 110d | 2023-04-19 | 2023-08-06 | 145 SS, 146 SS | 143d | 23d |
| 159 |  | Transporte de material seleccionado para zanja D<=1km | resource dependent | 10d | 2023-07-31 | 2023-08-09 | 140 SS | 140d | 20d |
| 160 |  | Transporte de material seleccionado para zanja D>1km | resource dependent | 10d | 2023-07-31 | 2023-08-09 | 140 SS | 140d | 20d |
| 153 |  | Transporte de material de préstamo (afirmado) D<=1km | resource dependent | 15d | 2023-08-15 | 2023-08-29 | 137 SS | 120d | 0d |
| 154 |  | Transporte de material de préstamo (afirmado) D>1km | resource dependent | 15d | 2023-08-15 | 2023-08-29 | 137 SS | 120d | 0d |
|  | 5 | **ACCESOS** |  |  | 2023-03-03 | 2023-03-08 |  |  |  |
|  | 1 | **Rellenos** |  |  | 2023-03-03 | 2023-03-08 |  |  |  |
| 163 |  | Relleno con material granular (incluye extracción de material, zarandeo y combinac | resource dependent | 4d | 2023-03-03 | 2023-03-06 | 4 | 28d | 0d |
| 164 |  | Relleno afirmado | resource dependent | 2d | 2023-03-07 | 2023-03-08 | 163 | 28d | 0d |
|  | 2 | **Transportes** |  |  | 2023-03-03 | 2023-03-08 |  |  |  |
| 168 |  | Transporte de material de préstamo cantera de rio (cuerpo de terraplén) D<=1km | resource dependent | 4d | 2023-03-03 | 2023-03-06 | 163 SS | 296d | 176d |
| 169 |  | Transporte de material de préstamo cantera de rio (cuerpo de terraplén) D>1km | resource dependent | 4d | 2023-03-03 | 2023-03-06 | 163 SS | 296d | 176d |
| 166 |  | Transporte de material de préstamo (afirmado) D<=1km | resource dependent | 2d | 2023-03-07 | 2023-03-08 | 164 SS | 294d | 174d |
| 167 |  | Transporte de material de préstamo (afirmado) D>1km | resource dependent | 2d | 2023-03-07 | 2023-03-08 | 164 SS | 294d | 174d |
|  | 6 | **DIQUE DI-PR-13-D-1** |  |  | 2023-06-13 | 2023-12-27 |  |  |  |
|  | 1 | **Excavaciones** |  |  | 2023-06-13 | 2023-09-21 |  |  |  |
| 172 |  | Desbroce | resource dependent | 10d | 2023-06-13 | 2023-06-22 | 360 | 0d |  |
| 177 |  | Conformación de material excedente en DMO | resource dependent | 10d | 2023-06-13 | 2023-06-22 | 190 FS-10d, 191 FS-10d | 188d |  |
| 173 |  | Excavación de cimentación | resource dependent | 90d | 2023-06-23 | 2023-09-20 | 172 | 0d |  |
| 175 |  | Excavación de uña | resource dependent | 90d | 2023-06-23 | 2023-09-20 | 172 | 0d |  |
| 176 |  | Conformación de material excedente en DME | resource dependent | 90d | 2023-06-23 | 2023-09-20 | 192 FS-90d, 193 FS-90d | 98d |  |
| 174 |  | Perfilado y conformación de Plataforma de fundación | resource dependent | 89d | 2023-06-25 | 2023-09-21 | 173 FS-88d, 175 FS-88d | 0d |  |

| ID | WBS | Activity | Type | Duration | Start | Finish | Predecessors | Total float | Free float |
| --- | --- | --- | --- | --- | --- | --- | --- | --- | --- |
|  | 2 | **Rellenos** |  |  | 2023-07-01 | 2023-12-27 |  |  |  |
| 182 |  | Perfilado de Talud del dique | resource dependent | 100d | 2023-07-01 | 2023-10-08 | 179 FS-103d | 0d |  |
| 179 |  | Relleno con material granular (incluye extracción de material, zarandeo y combinac | resource dependent | 100d | 2023-07-04 | 2023-10-11 | 174 FS-80d | 0d |  |
| 180 |  | Relleno sin compactar | resource dependent | 54d | 2023-10-20 | 2023-12-12 | 187 FS-50d, 188 FS-50d | 0d |  |
| 181 |  | Relleno afirmado | resource dependent | 15d | 2023-12-13 | 2023-12-27 | 180 | 0d |  |
|  | 3 | **Geotextil** |  |  | 2023-07-07 | 2023-12-07 |  |  |  |
| 185 |  | Zanja de anclaje | resource dependent | 153d | 2023-07-07 | 2023-12-06 | 182 FS-94d | 0d |  |
| 184 |  | Instalación de Geotextil 400 gr/m2 | resource dependent | 153d | 2023-07-08 | 2023-12-07 | 185 FS-152d | 0d |  |
|  | 4 | **Colocación de roca** |  |  | 2023-07-09 | 2023-12-08 |  |  |  |
| 187 |  | Colocación de roca en uña | resource dependent | 153d | 2023-07-09 | 2023-12-08 | 184 FS-152d | 0d |  |
| 188 |  | Colocación de roca en Talud | resource dependent | 153d | 2023-07-09 | 2023-12-08 | 184 FS-152d | 0d |  |
|  | 5 | **Transportes** |  |  | 2023-06-13 | 2023-12-27 |  |  |  |
| 190 |  | Transporte de material orgánico (a DMO) D<=1km | resource dependent | 10d | 2023-06-13 | 2023-06-22 | 172 SS | 188d | 0d |
| 191 |  | Transporte de material orgánico (a DMO) D>1km | resource dependent | 10d | 2023-06-13 | 2023-06-22 | 172 SS | 188d | 0d |
| 192 |  | Transporte de material excedente (dique provisional) D<=1km | resource dependent | 90d | 2023-06-23 | 2023-09-20 | 173 SS, 175 SS | 98d | 0d |
| 193 |  | Transporte de material excedente (dique provisional) D> 1km | resource dependent | 90d | 2023-06-23 | 2023-09-20 | 173 SS, 175 SS | 98d | 0d |
| 198 |  | Transporte de material de préstamo cantera de rio (cuerpo de terraplén) D<=1km | resource dependent | 100d | 2023-07-04 | 2023-10-11 | 179 SS | 77d |  |
| 199 |  | Transporte de material de préstamo cantera de rio (cuerpo de terraplén) D>1km | resource dependent | 100d | 2023-07-04 | 2023-10-11 | 179 SS | 77d |  |
| 196 |  | Transporte de roca D<=1km | resource dependent | 153d | 2023-07-09 | 2023-12-08 | 187 SS, 188 SS | 19d |  |
| 197 |  | Transporte de roca D>1km | resource dependent | 153d | 2023-07-09 | 2023-12-08 | 187 SS, 188 SS | 19d |  |
| 194 |  | Transporte de material de préstamo (afirmado) D<=1km | resource dependent | 15d | 2023-12-13 | 2023-12-27 | 181 SS | 0d |  |
| 195 |  | Transporte de material de préstamo (afirmado) D>1km | resource dependent | 15d | 2023-12-13 | 2023-12-27 | 181 SS | 0d |  |
|  | 7 | **DIQUE DI-PR-16-D** |  |  | 2023-06-13 | 2023-09-09 |  |  |  |
|  | 1 | **Excavaciones** |  |  | 2023-06-13 | 2023-07-02 |  |  |  |
| 202 |  | Desbroce | resource dependent | 5d | 2023-06-13 | 2023-06-17 | 360 | 88d | 0d |
| 207 |  | Conformación de material excedente en DMO | resource dependent | 5d | 2023-06-13 | 2023-06-17 | 220 FS-5d, 221 FS-5d | 193d |  |
| 203 |  | Excavación de cimentación | resource dependent | 13d | 2023-06-18 | 2023-06-30 | 202 | 88d | 0d |
| 205 |  | Excavación de uña | resource dependent | 13d | 2023-06-18 | 2023-06-30 | 202 | 88d | 0d |
| 204 |  | Perfilado y conformación de Plataforma de fundación | resource dependent | 12d | 2023-06-20 | 2023-07-01 | 203 FS-11d, 205 FS-11d | 88d | 0d |
| 206 |  | Conformación de material excedente en DME | resource dependent | 13d | 2023-06-20 | 2023-07-02 | 222 FS-13d, 223 FS-13d | 178d |  |

| ID | WBS | Activity | Type | Duration | Start | Finish | Predecessors | Total float | Free float |
| --- | --- | --- | --- | --- | --- | --- | --- | --- | --- |
|  | 2 | **Rellenos** |  |  | 2023-07-02 | 2023-09-09 |  |  |  |
| 209 |  | Relleno con material granular (incluye extracción de material, zarandeo y combinac | resource dependent | 20d | 2023-07-02 | 2023-07-21 | 204 | 88d | 0d |
| 212 |  | Perfilado de Talud del dique | resource dependent | 20d | 2023-07-03 | 2023-07-22 | 209 FS-19d | 88d | 0d |
| 210 |  | Relleno sin compactar | resource dependent | 7d | 2023-08-29 | 2023-09-04 | 217, 218 | 88d | 0d |
| 211 |  | Relleno afirmado | resource dependent | 5d | 2023-09-05 | 2023-09-09 | 210 | 88d | 0d |
|  | 3 | **Geotextil** |  |  | 2023-07-20 | 2023-08-27 |  |  |  |
| 215 |  | Zanja de anclaje | resource dependent | 38d | 2023-07-20 | 2023-08-26 | 212 FS-3d, 36 | 88d | 0d |
| 214 |  | Instalación de Geotextil 400 gr/m2 | resource dependent | 38d | 2023-07-21 | 2023-08-27 | 215 FS-37d, 35 | 88d | 0d |
|  | 4 | **Colocación de roca** |  |  | 2023-07-22 | 2023-08-28 |  |  |  |
| 217 |  | Colocación de roca en uña | resource dependent | 38d | 2023-07-22 | 2023-08-28 | 214 FS-37d, 38 | 88d | 0d |
| 218 |  | Colocación de roca en Talud | resource dependent | 38d | 2023-07-22 | 2023-08-28 | 214 FS-37d, 39 | 88d | 0d |
|  | 5 | **Transportes** |  |  | 2023-06-13 | 2023-09-09 |  |  |  |
| 220 |  | Transporte de material orgánico (a DMO) D<=1km | resource dependent | 5d | 2023-06-13 | 2023-06-17 | 202 SS | 193d | 0d |
| 221 |  | Transporte de material orgánico (a DMO) D>1km | resource dependent | 5d | 2023-06-13 | 2023-06-17 | 202 SS | 193d | 0d |
| 222 |  | Transporte de material excedente (dique provisional) D<=1km | resource dependent | 13d | 2023-06-20 | 2023-07-02 | 203 SS, 204 SS | 178d | 0d |
| 223 |  | Transporte de material excedente (dique provisional) D> 1km | resource dependent | 13d | 2023-06-20 | 2023-07-02 | 203 SS, 204 SS | 178d | 0d |
| 228 |  | Transporte de material de préstamo cantera de rio (cuerpo de terraplén) D<=1km | resource dependent | 20d | 2023-07-02 | 2023-07-21 | 209 SS | 159d |  |
| 229 |  | Transporte de material de préstamo cantera de rio (cuerpo de terraplén) D>1km | resource dependent | 20d | 2023-07-02 | 2023-07-21 | 209 SS | 159d |  |
| 226 |  | Transporte de roca D<=1km | resource dependent | 38d | 2023-07-22 | 2023-08-28 | 217 SS, 218 SS | 121d |  |
| 227 |  | Transporte de roca D>1km | resource dependent | 38d | 2023-07-22 | 2023-08-28 | 217 SS, 218 SS | 121d |  |
| 224 |  | Transporte de material de préstamo (afirmado) D<=1km | resource dependent | 5d | 2023-09-05 | 2023-09-09 | 211 SS | 109d |  |
| 225 |  | Transporte de material de préstamo (afirmado) D>1km | resource dependent | 5d | 2023-09-05 | 2023-09-09 | 211 SS | 109d |  |
|  | 8 | **DIQUE DI-PR-17-D** |  |  | 2023-06-18 | 2023-09-30 |  |  |  |
|  | 1 | **Excavaciones** |  |  | 2023-06-18 | 2023-07-27 |  |  |  |
| 232 |  | Desbroce | resource dependent | 13d | 2023-06-18 | 2023-06-30 | 202 | 88d | 0d |
| 237 |  | Conformación de material excedente en DMO | resource dependent | 13d | 2023-06-18 | 2023-06-30 | 250 FS-13d, 251 FS-13d | 180d |  |
| 233 |  | Excavación de cimentación | resource dependent | 26d | 2023-07-01 | 2023-07-26 | 203, 232 | 88d | 0d |
| 235 |  | Excavación de uña | resource dependent | 26d | 2023-07-01 | 2023-07-26 | 205, 232 | 88d | 0d |
| 236 |  | Conformación de material excedente en DME | resource dependent | 26d | 2023-07-01 | 2023-07-26 | 252 FS-26d, 253 FS-26d | 154d |  |
| 234 |  | Perfilado y conformación de Plataforma de fundación | resource dependent | 26d | 2023-07-02 | 2023-07-27 | 233 FS-25d, 235 FS-25d, 204 | 88d | 0d |

| ID | WBS | Activity | Type | Duration | Start | Finish | Predecessors | Total float | Free float |
| --- | --- | --- | --- | --- | --- | --- | --- | --- | --- |
|  | 2 | **Rellenos** |  |  | 2023-07-22 | 2023-09-30 |  |  |  |
| 239 |  | Relleno con material granular (incluye extracción de material, zarandeo y combinac | resource dependent | 35d | 2023-07-22 | 2023-08-25 | 209, 234 FS-6d | 88d | 0d |
| 242 |  | Perfilado de Talud del dique | resource dependent | 35d | 2023-07-23 | 2023-08-26 | 212, 239 FS-34d | 88d | 0d |
| 240 |  | Relleno sin compactar | resource dependent | 10d | 2023-09-14 | 2023-09-23 | 211 FS+4d, 247 FS-9d, 248 FS-9d | 88d | 0d |
| 241 |  | Relleno afirmado | resource dependent | 7d | 2023-09-24 | 2023-09-30 | 240 | 88d | 0d |
|  | 3 | **Geotextil** |  |  | 2023-08-27 | 2023-09-21 |  |  |  |
| 245 |  | Zanja de anclaje | resource dependent | 25d | 2023-08-27 | 2023-09-20 | 215, 242 | 88d | 0d |
| 244 |  | Instalación de Geotextil 400 gr/m2 | resource dependent | 25d | 2023-08-28 | 2023-09-21 | 245 FS-24d | 88d | 0d |
|  | 4 | **Colocación de roca** |  |  | 2023-08-29 | 2023-09-22 |  |  |  |
| 247 |  | Colocación de roca en uña | resource dependent | 25d | 2023-08-29 | 2023-09-22 | 244 FS-24d | 88d | 0d |
| 248 |  | Colocación de roca en Talud | resource dependent | 25d | 2023-08-29 | 2023-09-22 | 244 FS-24d | 88d | 0d |
|  | 5 | **Transportes** |  |  | 2023-06-18 | 2023-09-30 |  |  |  |
| 250 |  | Transporte de material orgánico (a DMO) D<=1km | resource dependent | 13d | 2023-06-18 | 2023-06-30 | 232 SS | 180d | 0d |
| 251 |  | Transporte de material orgánico (a DMO) D>1km | resource dependent | 13d | 2023-06-18 | 2023-06-30 | 232 SS | 180d | 0d |
| 252 |  | Transporte de material excedente (dique provisional) D<=1km | resource dependent | 26d | 2023-07-01 | 2023-07-26 | 233 SS, 235 SS | 154d | 0d |
| 253 |  | Transporte de material excedente (dique provisional) D> 1km | resource dependent | 26d | 2023-07-01 | 2023-07-26 | 233 SS, 235 SS | 154d | 0d |
| 258 |  | Transporte de material de préstamo cantera de rio (cuerpo de terraplén) D<=1km | resource dependent | 35d | 2023-07-22 | 2023-08-25 | 239 SS | 124d |  |
| 259 |  | Transporte de material de préstamo cantera de rio (cuerpo de terraplén) D>1km | resource dependent | 35d | 2023-07-22 | 2023-08-25 | 239 SS | 124d |  |
| 256 |  | Transporte de roca D<=1km | resource dependent | 25d | 2023-08-29 | 2023-09-22 | 247 SS, 248 SS | 96d |  |
| 257 |  | Transporte de roca D>1km | resource dependent | 25d | 2023-08-29 | 2023-09-22 | 247 SS, 248 SS | 96d |  |
| 254 |  | Transporte de material de préstamo (afirmado) D<=1km | resource dependent | 7d | 2023-09-24 | 2023-09-30 | 241 SS | 88d |  |
| 255 |  | Transporte de material de préstamo (afirmado) D>1km | resource dependent | 7d | 2023-09-24 | 2023-09-30 | 241 SS | 88d |  |
|  | 9 | **DIQUE DI-PR-18-D** |  |  | 2023-06-13 | 2023-11-29 |  |  |  |
|  | 1 | **Excavaciones** |  |  | 2023-06-13 | 2023-08-10 |  |  |  |
| 262 |  | Desbroce | resource dependent | 5d | 2023-06-13 | 2023-06-17 | 360 | 28d | 0d |
| 267 |  | Conformación de material excedente en DMO | resource dependent | 5d | 2023-06-13 | 2023-06-17 | 280 FS-5d, 281 FS-5d | 193d |  |
| 263 |  | Excavación de cimentación | resource dependent | 53d | 2023-06-18 | 2023-08-09 | 262 | 28d | 0d |
| 265 |  | Excavación de uña | resource dependent | 53d | 2023-06-18 | 2023-08-09 | 262 | 28d | 0d |
| 266 |  | Conformación de material excedente en DME | resource dependent | 53d | 2023-06-18 | 2023-08-09 | 282 FS-53d, 283 FS-53d | 140d |  |
| 264 |  | Perfilado y conformación de Plataforma de fundación | resource dependent | 52d | 2023-06-20 | 2023-08-10 | 263 FS-51d, 265 FS-51d | 28d | 0d |

| ID | WBS | Activity | Type | Duration | Start | Finish | Predecessors | Total float | Free float |
| --- | --- | --- | --- | --- | --- | --- | --- | --- | --- |
|  | 2 | **Rellenos** |  |  | 2023-07-28 | 2023-11-29 |  |  |  |
| 269 |  | Relleno con material granular (incluye extracción de material, zarandeo y combinac | resource dependent | 62d | 2023-07-28 | 2023-09-27 | 264 FS-14d | 28d | 0d |
| 272 |  | Perfilado de Talud del dique | resource dependent | 62d | 2023-07-29 | 2023-09-28 | 269 FS-61d | 28d | 0d |
| 270 |  | Relleno sin compactar | resource dependent | 19d | 2023-11-04 | 2023-11-22 | 277, 278 | 28d | 0d |
| 271 |  | Relleno afirmado | resource dependent | 7d | 2023-11-23 | 2023-11-29 | 270 | 28d | 0d |
|  | 3 | **Geotextil** |  |  | 2023-08-05 | 2023-11-02 |  |  |  |
| 275 |  | Zanja de anclaje | resource dependent | 89d | 2023-08-05 | 2023-11-01 | 272 FS-55d, 143 | 28d | 0d |
| 274 |  | Instalación de Geotextil 400 gr/m2 | resource dependent | 89d | 2023-08-06 | 2023-11-02 | 275 FS-88d, 142 | 28d | 0d |
|  | 4 | **Colocación de roca** |  |  | 2023-08-07 | 2023-11-03 |  |  |  |
| 277 |  | Colocación de roca en uña | resource dependent | 89d | 2023-08-07 | 2023-11-03 | 274 FS-88d, 145 | 28d | 0d |
| 278 |  | Colocación de roca en Talud | resource dependent | 89d | 2023-08-07 | 2023-11-03 | 274 FS-88d, 146 | 28d | 0d |
|  | 5 | **Transportes** |  |  | 2023-06-13 | 2023-11-29 |  |  |  |
| 280 |  | Transporte de material orgánico (a DMO) D<=1km | resource dependent | 5d | 2023-06-13 | 2023-06-17 | 262 SS | 193d | 0d |
| 281 |  | Transporte de material orgánico (a DMO) D>1km | resource dependent | 5d | 2023-06-13 | 2023-06-17 | 262 SS | 193d | 0d |
| 282 |  | Transporte de material excedente (dique provisional) D<=1km | resource dependent | 53d | 2023-06-18 | 2023-08-09 | 263 SS, 265 SS | 140d | 0d |
| 283 |  | Transporte de material excedente (dique provisional) D> 1km | resource dependent | 53d | 2023-06-18 | 2023-08-09 | 263 SS, 265 SS | 140d | 0d |
| 288 |  | Transporte de material de préstamo cantera de rio (cuerpo de terraplén) D<=1km | resource dependent | 62d | 2023-07-28 | 2023-09-27 | 269 SS | 91d |  |
| 289 |  | Transporte de material de préstamo cantera de rio (cuerpo de terraplén) D>1km | resource dependent | 62d | 2023-07-28 | 2023-09-27 | 269 SS | 91d |  |
| 286 |  | Transporte de roca D<=1km | resource dependent | 89d | 2023-08-07 | 2023-11-03 | 277 SS, 278 SS | 54d |  |
| 287 |  | Transporte de roca D>1km | resource dependent | 89d | 2023-08-07 | 2023-11-03 | 277 SS, 278 SS | 54d |  |
| 284 |  | Transporte de material de préstamo (afirmado) D<=1km | resource dependent | 7d | 2023-11-23 | 2023-11-29 | 271 SS | 28d |  |
| 285 |  | Transporte de material de préstamo (afirmado) D>1km | resource dependent | 7d | 2023-11-23 | 2023-11-29 | 271 SS | 28d |  |
|  | 5 | **OBRAS CIVILES** |  |  | 2023-02-01 | 2023-12-27 |  |  |  |
| 371 |  | Trazo y replanteo de interferencia | resource dependent | 330d | 2023-02-01 | 2023-12-27 | 2 | 0d |  |
| 372 |  | Desvío provisional con tubería | resource dependent | 41d | 2023-02-01 | 2023-03-13 | 374 FS-13d | 0d |  |
| 374 |  | Limpieza de terreno manual | resource dependent | 13d | 2023-02-01 | 2023-02-13 | 2, 371 SS | 0d |  |
| 373 |  | Desvío provisional en tierras | resource dependent | 86d | 2023-03-14 | 2023-06-07 | 372 | 0d |  |
| 375 |  | Excavaciones no clasificada para estructuras | resource dependent | 34d | 2023-03-29 | 2023-05-01 | 373 FS-71d | 0d |  |
| 376 |  | Excavacion no clasificada de zanja | resource dependent | 156d | 2023-05-02 | 2023-10-04 | 375 | 0d |  |
| 377 |  | Relleno estructural | resource dependent | 76d | 2023-07-27 | 2023-10-10 | 376 FS-70d | 0d |  |
| 384 |  | Encofrado y Desencofrado Caravista | resource dependent | 39d | 2023-09-11 | 2023-10-19 | 377 FS-30d | 5d | 0d |
| 386 |  | Acero de refuerzo f'y=4200kg/cm2 | resource dependent | 90d | 2023-09-11 | 2023-12-09 | 377 FS-30d | 18d |  |
| 378 |  | Suministro de roca (Alcantarillas) | resource dependent | 33d | 2023-10-11 | 2023-11-12 | 377 | 26d | 0d |
| 380 |  | Concreto de Nivelacion (f'c=100 kg/cm2) | resource dependent | 10d | 2023-10-11 | 2023-10-20 | 377 | 0d |  |
| 390 |  | Cama de arena e=0.20m | resource dependent | 21d | 2023-10-11 | 2023-10-31 | 377 | 0d |  |
| 385 |  | Encofrado y Desencofrado Cara Oculta | resource dependent | 51d | 2023-10-20 | 2023-12-09 | 384 | 5d | 0d |
| 381 |  | Concreto Clase F (f'c=140 kg/cm2) | resource dependent | 19d | 2023-10-21 | 2023-11-08 | 380 | 0d |  |
| 387 |  | Emboquillado de piedra e=0.20m | resource dependent | 23d | 2023-10-27 | 2023-11-18 | 383 FS-50d | 0d |  |
| 391 |  | Tubería HDPE Corrugada Ø=900mm (Suministro e instalación) | resource dependent | 4d | 2023-11-01 | 2023-11-04 | 390 | 0d |  |
| 392 |  | Tubería HDPE Corrugada Ø=1200mm (Suministro e instalación) | resource dependent | 7d | 2023-11-05 | 2023-11-11 | 391 | 0d |  |
| 382 |  | Concreto Clase C (f'c=280 kg/cm2) Premezclado - Cimientos reforzados | resource dependent | 7d | 2023-11-09 | 2023-11-15 | 381 | 0d |  |
| 393 |  | Compuertas Charnela Ø900 (Suministro e instalacion) | resource dependent | 12d | 2023-11-12 | 2023-11-23 | 392 | 0d |  |
| 379 |  | Colocación de roca en uña (Alcantarillas) | resource dependent | 19d | 2023-11-13 | 2023-12-01 | 378 | 26d |  |
| 383 |  | Concreto Clase C (f'c=280 kg/cm2) Premezclado - Muros de contencion | resource dependent | 30d | 2023-11-16 | 2023-12-15 | 382 | 0d |  |
| 388 |  | Emboquillado de piedra e=0.30m | resource dependent | 27d | 2023-11-19 | 2023-12-15 | 387 | 0d |  |
| 394 |  | Compuertas Charnela Ø1200 (Suministro e instalacion) | resource dependent | 17d | 2023-11-24 | 2023-12-10 | 393 | 0d |  |
| 395 |  | Compuerta metálica tipo tarjeta 1.00x1.00m (Suministro e instalacion) | resource dependent | 9d | 2023-12-11 | 2023-12-19 | 394 | 0d |  |
| 389 |  | Emboquillado de piedra e=0.50m | resource dependent | 12d | 2023-12-16 | 2023-12-27 | 388 | 0d |  |
| 396 |  | Sello en juntas | resource dependent | 2d | 2023-12-20 | 2023-12-21 | 395 | 0d |  |
| 397 |  | Waterstop (anillos de estanqueidad) | resource dependent | 3d | 2023-12-22 | 2023-12-24 | 396 | 0d |  |
| 398 |  | Pintura bituminosa | resource dependent | 2d | 2023-12-25 | 2023-12-26 | 397 | 0d |  |
| 399 |  | Relleno con material granular (incluye extracción de material, zarandeo y combinac | resource dependent | 1d | 2023-12-27 | 2023-12-27 | 398 | 0d |  |

| ID | WBS | Activity | Type | Duration | Start | Finish | Predecessors | Total float |
| --- | --- | --- | --- | --- | --- | --- | --- | --- |
|  | 6 | **ACCESOS** |  |  | 2023-12-10 | 2023-12-27 |  |  |
|  | 1 | **Superficie de rodadura** |  |  | 2023-12-10 | 2023-12-27 |  |  |
| 403 |  | Encofrado y desencofrado pavimento rígido e=0.15m | resource dependent | 13d | 2023-12-10 | 2023-12-22 | 385 | 5d |
| 405 |  | Concreto Ciclopeo f'c=210 kg/cm2 + 30% PM | resource dependent | 8d | 2023-12-16 | 2023-12-23 | 383 | 0d |
| 402 |  | Concreto clase C (f'c=280 kg/cm2) en losa | resource dependent | 3d | 2023-12-24 | 2023-12-26 | 405 | 0d |
| 404 |  | Junta en Pavimentos con Pasadores | resource dependent | 1d | 2023-12-27 | 2023-12-27 | 402 | 0d |
