# HABILITACIÓN DE ACCESOS Y PLATAFORMAS, Y MOVIMIENTO DE TIERRAS II PARTE - CUENCA HUAURA

Schedule from MS Project, 2023-02-01 to 2023-12-27, 10 hours a day.

## Calendars

- 2302: Mon-Sun 07:00-12:00, 13:00-18:00.

## Schedule

| ID | WBS | Task | Type | Duration | Start | Finish | Predecessors | Total slack | Free slack |
| --- | --- | --- | --- | --- | --- | --- | --- | --- | --- |
| 1 | 1 | **HITOS DEL PROYECTO** |  | 330d | 2023-02-01 | 2023-12-27 |  | 0d |  |
| 2 | 1.1 | Hito 1: Inicio de obra - Acceso al Sitio | milestone | 0d | 2023-02-01 | 2023-02-01 |  | 0d |  |
| 3 | 1.2 | Hito 2: Inicio de Habilitación y Mejoramiento de accesos | milestone | 0d | 2023-02-15 | 2023-02-15 | 2FS+15d | 0d |  |
| 4 | 1.3 | Hito 3: Inicio de Movimiento de Tierras - Dique Paquete 2 | milestone | 0d | 2023-03-02 | 2023-03-02 | 3FS+15d | 28d | 0d |
| 5 | 1.4 | Hito 4: Culminación de Diques Paquete 2 | milestone | 0d | 2023-08-29 | 2023-08-29 | 4FS+180d, 26, 27, 31, 33, 46, 47, 48, 49, 50, 51, 52, 53, 60, 61, 65, 68, 81, 82, 83, 84, 85, 86, 87, 88, 95, 96, 97, 101, 104, 116, 117, 118, 119, 120, 121, 122, 123, 131, 132, 133, 137, 139, 140, 153, 154, 155, 156, 157, 158, 159, 160, 166, 167, 168, 169 | 120d |  |
| 6 | 1.5 | Hito 5: Inicio de Movimiento de Tierras - Dique Paquete 3 | milestone | 0d | 2023-05-16 | 2023-05-16 | 3FS+90d | 0d |  |
| 7 | 1.6 | Hito 6: Culminación de Diques Paquete 3 | milestone | 0d | 2023-12-27 | 2023-12-27 | 6FS+225d, 176, 177, 181, 194, 195, 196, 197, 198, 199, 206, 207, 211, 224, 225, 226, 227, 228, 229, 236, 237, 241, 254, 255, 256, 257, 258, 259, 266, 267, 271, 284, 285, 286, 287, 288, 289, 296, 297, 298, 302, 304, 316, 317, 318, 319, 320, 321, 328, 329, 333, 346, 347, 348, 349, 350, 351 | 0d |  |
| 8 | 2 | **OBRAS PROVISIONALES** |  | 330d | 2023-02-01 | 2023-12-27 |  | 0d |  |
| 9 | 2.1 | Campamento Provisional de Obra |  | 30d | 2023-02-01 | 2023-03-02 | 2 | 300d |  |
| 10 | 2.2 | Movilización y Desmovilización de maquinaria pesada |  | 330d | 2023-02-01 | 2023-12-27 | 2 | 0d |  |
| 11 | 2.3 | Mejoramiento y Habilitación de caminos de acceso |  | 35d | 2023-03-03 | 2023-04-06 | 12 | 0d |  |
| 12 | 2.4 | Limpieza manual de material vegetal y de residuos |  | 15d | 2023-02-16 | 2023-03-02 | 3 | 0d |  |
| 13 | 2.5 | Mantenimiento de caminos de acceso |  | 240d | 2023-05-02 | 2023-12-27 | 15 | 0d |  |
| 14 | 2.6 | Tubería HDPE Corrugada Ø=630mm, para caminos de acceso (o similar) |  | 10d | 2023-04-07 | 2023-04-16 | 11 | 0d |  |
| 15 | 2.7 | Tubería HDPE Corrugada Ø=1000mm, para caminos de acceso (o similar) |  | 15d | 2023-04-17 | 2023-05-01 | 14 | 0d |  |
| 16 | 3 | **TOPOGRAFIA** |  | 330d | 2023-02-01 | 2023-12-27 |  | 0d |  |
| 17 | 3.1 | Trazo y replanteo durante la obra |  | 330d | 2023-02-01 | 2023-12-27 | 2 | 0d |  |
| 18 | 4 | **CONSTRUCCIÓN DE DIQUES** |  | 300d | 2023-03-03 | 2023-12-27 |  | 0d |  |
| 19 | 4.1 | **DIQUE DI-PR-13-D** |  | 144d | 2023-03-19 | 2023-08-09 |  | 88d |  |
| 20 | 4.1.1 | **Excavaciones** |  | 31d | 2023-03-19 | 2023-04-18 |  | 88d |  |
| 21 | 4.1.1.1 | Desbroce |  | 5d | 2023-03-19 | 2023-03-23 | 91 | 88d | 0d |
| 22 | 4.1.1.2 | Remoción de dique existente |  | 20d | 2023-03-24 | 2023-04-12 | 21 | 88d | 0d |
| 23 | 4.1.1.3 | Excavación de cimentación |  | 18d | 2023-03-31 | 2023-04-17 | 21, 22FS-13d, 92 | 88d | 0d |
| 24 | 4.1.1.4 | Perfilado y conformación de Plataforma de fundación |  | 18d | 2023-04-01 | 2023-04-18 | 23FS-17d, 25FS-17d, 93 | 88d | 0d |
| 25 | 4.1.1.5 | Excavación de uña |  | 18d | 2023-03-31 | 2023-04-17 | 21, 22FS-13d, 94 | 88d | 0d |
| 26 | 4.1.1.6 | Conformación de material excedente en DME |  | 18d | 2023-03-31 | 2023-04-17 | 44FS-18d, 45FS-18d | 254d | 134d |
| 27 | 4.1.1.7 | Conformación de material excedente en DMO |  | 5d | 2023-03-19 | 2023-03-23 | 42FS-5d, 43FS-5d | 279d | 159d |

| ID | WBS | Task | Duration | Start | Finish | Predecessors | Total slack | Free slack |
| --- | --- | --- | --- | --- | --- | --- | --- | --- |
| 28 | 4.1.2 | **Rellenos** | 122d | 2023-04-10 | 2023-08-09 |  | 88d |  |
| 29 | 4.1.2.1 | Relleno con material granular (incluye extracción de material, zarandeo y combinación de material) | 39d | 2023-04-10 | 2023-05-18 | 24FS-9d, 99 | 88d | 0d |
| 30 | 4.1.2.2 | Relleno sin compactar | 12d | 2023-07-22 | 2023-08-02 | 38, 39 | 140d | 0d |
| 31 | 4.1.2.3 | Relleno afirmado | 7d | 2023-08-03 | 2023-08-09 | 30 | 140d | 0d |
| 32 | 4.1.2.4 | Perfilado de Talud del dique | 39d | 2023-04-11 | 2023-05-19 | 29FS-38d, 102 | 88d | 0d |
| 33 | 4.1.2.5 | Grava para Drenaje | 7d | 2023-07-22 | 2023-07-28 | 38, 39 | 152d | 0d |
| 34 | 4.1.3 | **Geotextil** | 69d | 2023-05-13 | 2023-07-20 |  | 88d |  |
| 35 | 4.1.3.1 | Instalación de Geotextil 400 gr/m2 | 68d | 2023-05-14 | 2023-07-20 | 36FS-67d | 88d | 0d |
| 36 | 4.1.3.2 | Zanja de anclaje | 68d | 2023-05-13 | 2023-07-19 | 32FS-7d, 107 | 88d | 0d |
| 37 | 4.1.4 | **Colocación de roca** | 115d | 2023-03-29 | 2023-07-21 |  | 88d |  |
| 38 | 4.1.4.1 | Colocación de roca en uña | 68d | 2023-05-15 | 2023-07-21 | 35FS-67d, 40FS-11d | 88d | 0d |
| 39 | 4.1.4.2 | Colocación de roca en Talud | 68d | 2023-05-15 | 2023-07-21 | 35FS-67d, 40FS-11d | 88d | 0d |
| 40 | 4.1.4.3 | Extracción y Selección de Rocas Reutilizables (50% de roca utilizable) | 58d | 2023-03-29 | 2023-05-25 | 22FS-15d | 88d | 0d |
| 41 | 4.1.5 | **Transportes** | 144d | 2023-03-19 | 2023-08-09 |  | 140d |  |
| 42 | 4.1.5.1 | Transporte de material orgánico (a DMO) D<=1km | 5d | 2023-03-19 | 2023-03-23 | 21SS | 279d | 0d |
| 43 | 4.1.5.2 | Transporte de material orgánico (a DMO) D>1km | 5d | 2023-03-19 | 2023-03-23 | 21SS | 279d | 0d |
| 44 | 4.1.5.3 | Transporte de material excedente (dique provisional) D<=1km | 18d | 2023-03-31 | 2023-04-17 | 23SS, 25SS | 254d | 0d |
| 45 | 4.1.5.4 | Transporte de material excedente (dique provisional) D> 1km | 18d | 2023-03-31 | 2023-04-17 | 23SS, 25SS | 254d | 0d |
| 46 | 4.1.5.5 | Transporte de material de préstamo (afirmado) D<=1km | 7d | 2023-08-03 | 2023-08-09 | 31SS | 140d | 20d |
| 47 | 4.1.5.6 | Transporte de material de préstamo (afirmado) D>1km | 7d | 2023-08-03 | 2023-08-09 | 31SS | 140d | 20d |
| 48 | 4.1.5.7 | Transporte de roca D<=1km | 68d | 2023-05-15 | 2023-07-21 | 38SS, 39SS | 159d | 39d |
| 49 | 4.1.5.8 | Transporte de roca D>1km | 68d | 2023-05-15 | 2023-07-21 | 38SS, 39SS | 159d | 39d |
| 50 | 4.1.5.9 | Transporte de material de préstamo cantera de rio (cuerpo de terraplén) D<=1km | 39d | 2023-04-10 | 2023-05-18 | 29SS | 223d | 103d |
| 51 | 4.1.5.10 | Transporte de material de préstamo cantera de rio (cuerpo de terraplén) D>1km | 39d | 2023-04-10 | 2023-05-18 | 29SS | 223d | 103d |
| 52 | 4.1.5.11 | Transporte de material seleccionado para zanja D<=1km | 7d | 2023-07-22 | 2023-07-28 | 33SS | 152d | 32d |
| 53 | 4.1.5.12 | Transporte de material seleccionado para zanja D>1km | 7d | 2023-07-22 | 2023-07-28 | 33SS | 152d | 32d |

| ID | WBS | Task | Duration | Start | Finish | Predecessors | Total slack | Free slack |
| --- | --- | --- | --- | --- | --- | --- | --- | --- |
| 54 | 4.2 | **DIQUE DI-PR-25-I** | 41d | 2023-03-09 | 2023-04-18 |  | 88d |  |
| 55 | 4.2.1 | **Excavaciones** | 13d | 2023-03-09 | 2023-03-21 |  | 88d |  |
| 56 | 4.2.1.1 | Desbroce | 5d | 2023-03-09 | 2023-03-13 | 164 | 88d | 0d |
| 57 | 4.2.1.2 | Excavación de cimentación | 5d | 2023-03-14 | 2023-03-18 | 56 | 88d | 0d |
| 58 | 4.2.1.3 | Perfilado y conformación de Plataforma de fundación | 4d | 2023-03-16 | 2023-03-19 | 57FS-3d, 59FS-3d, 62FS-6d | 88d | 0d |
| 59 | 4.2.1.4 | Excavación de uña | 5d | 2023-03-14 | 2023-03-18 | 56 | 88d | 0d |
| 60 | 4.2.1.5 | Conformación de material excedente en DME | 5d | 2023-03-14 | 2023-03-18 | 79FS-5d, 80FS-5d | 284d | 164d |
| 61 | 4.2.1.6 | Conformación de material excedente en DMO | 5d | 2023-03-09 | 2023-03-13 | 77FS-5d, 78FS-5d | 289d | 169d |
| 62 | 4.2.1.7 | Excavación Localizada - Sobreexcavación | 3d | 2023-03-19 | 2023-03-21 | 57, 59 | 88d | 0d |
| 63 | 4.2.2 | **Rellenos** | 30d | 2023-03-20 | 2023-04-18 |  | 88d |  |
| 64 | 4.2.2.1 | Relleno con material granular (incluye extracción de material, zarandeo y combinac | 7d | 2023-03-20 | 2023-03-26 | 58 | 88d | 0d |
| 65 | 4.2.2.2 | Relleno sin compactar | 3d | 2023-04-11 | 2023-04-13 | 74, 75 | 253d | 0d |
| 66 | 4.2.2.3 | Relleno afirmado | 5d | 2023-04-14 | 2023-04-18 | 65, 69 | 253d | 0d |
| 67 | 4.2.2.4 | Perfilado de Talud del dique | 7d | 2023-03-21 | 2023-03-27 | 64FS-6d | 88d | 0d |
| 68 | 4.2.2.5 | Relleno con material seleccionado (incluye extracción de material, zarandeo y combinación de material) en sobreexcavación | 3d | 2023-03-27 | 2023-03-29 | 64 | 273d | 153d |
| 69 | 4.2.2.6 | Grava para Drenaje | 3d | 2023-04-11 | 2023-04-13 | 74, 75 | 253d | 0d |
| 70 | 4.2.3 | **Geotextil** | 13d | 2023-03-28 | 2023-04-09 |  | 88d |  |
| 71 | 4.2.3.1 | Instalación de Geotextil 400 gr/m2 | 12d | 2023-03-29 | 2023-04-09 | 72FS-11d | 215d | 0d |
| 72 | 4.2.3.2 | Zanja de anclaje | 12d | 2023-03-28 | 2023-04-08 | 67 | 88d | 0d |
| 73 | 4.2.4 | **Colocación de roca** | 12d | 2023-03-30 | 2023-04-10 |  | 215d |  |
| 74 | 4.2.4.1 | Colocación de roca en uña | 12d | 2023-03-30 | 2023-04-10 | 71FS-11d | 215d | 0d |
| 75 | 4.2.4.2 | Colocación de roca en Talud | 12d | 2023-03-30 | 2023-04-10 | 71FS-11d | 215d | 0d |
| 76 | 4.2.5 | **Transportes** | 41d | 2023-03-09 | 2023-04-18 |  | 253d |  |
| 77 | 4.2.5.1 | Transporte de material orgánico (a DMO) D<=1km | 5d | 2023-03-09 | 2023-03-13 | 56SS | 289d | 0d |
| 78 | 4.2.5.2 | Transporte de material orgánico (a DMO) D>1km | 5d | 2023-03-09 | 2023-03-13 | 56SS | 289d | 0d |
| 79 | 4.2.5.3 | Transporte de material excedente (dique provisional) D<=1km | 5d | 2023-03-14 | 2023-03-18 | 57SS, 59SS | 284d | 0d |
| 80 | 4.2.5.4 | Transporte de material excedente (dique provisional) D> 1km | 5d | 2023-03-14 | 2023-03-18 | 57SS, 59SS | 284d | 0d |
| 81 | 4.2.5.5 | Transporte de material de préstamo (afirmado) D<=1km | 5d | 2023-04-14 | 2023-04-18 | 66SS | 253d | 133d |
| 82 | 4.2.5.6 | Transporte de material de préstamo (afirmado) D>1km | 5d | 2023-04-14 | 2023-04-18 | 66SS | 253d | 133d |
| 83 | 4.2.5.7 | Transporte de roca D<=1km | 12d | 2023-03-30 | 2023-04-10 | 74SS, 75SS | 261d | 141d |
| 84 | 4.2.5.8 | Transporte de roca D>1km | 12d | 2023-03-30 | 2023-04-10 | 74SS, 75SS | 261d | 141d |
| 85 | 4.2.5.9 | Transporte de material de préstamo cantera de rio (cuerpo de terraplén) D<=1km | 7d | 2023-03-20 | 2023-03-26 | 64SS | 276d | 156d |
| 86 | 4.2.5.10 | Transporte de material de préstamo cantera de rio (cuerpo de terraplén) D>1km | 7d | 2023-03-20 | 2023-03-26 | 64SS | 276d | 156d |
| 87 | 4.2.5.11 | Transporte de material seleccionado para zanja D<=1km | 3d | 2023-04-11 | 2023-04-13 | 69SS | 258d | 138d |
| 88 | 4.2.5.12 | Transporte de material seleccionado para zanja D>1km | 3d | 2023-04-11 | 2023-04-13 | 69SS | 258d | 138d |

| ID | WBS | Task | Duration | Start | Finish | Predecessors | Total slack | Free slack |
| --- | --- | --- | --- | --- | --- | --- | --- | --- |
| 89 | 4.3 | **DIQUE DI-PR-24-D** | 74d | 2023-03-14 | 2023-05-26 |  | 88d |  |
| 90 | 4.3.1 | **Excavaciones** | 17d | 2023-03-14 | 2023-03-30 |  | 88d |  |
| 91 | 4.3.1.1 | Desbroce | 5d | 2023-03-14 | 2023-03-18 | 56 | 88d | 0d |
| 92 | 4.3.1.2 | Excavación de cimentación | 12d | 2023-03-19 | 2023-03-30 | 57, 91 | 88d | 0d |
| 93 | 4.3.1.3 | Perfilado y conformación de Plataforma de fundación | 11d | 2023-03-20 | 2023-03-30 | 92FS-11d, 94FS-11d | 88d | 0d |
| 94 | 4.3.1.4 | Excavación de uña | 12d | 2023-03-19 | 2023-03-30 | 59, 91 | 88d | 0d |
| 95 | 4.3.1.5 | Conformación de material excedente en DME | 12d | 2023-03-19 | 2023-03-30 | 114FS-12d, 115FS-12d | 272d | 152d |
| 96 | 4.3.1.6 | Conformación de material excedente en DMO | 5d | 2023-03-14 | 2023-03-18 | 112FS-5d, 113FS-5d | 284d | 164d |
| 97 | 4.3.1.7 | Excavación Localizada - Sobreexcavación | 3d | 2023-03-28 | 2023-03-30 | 92FS-3d, 94FS-3d | 272d | 152d |
| 98 | 4.3.2 | **Rellenos** | 61d | 2023-03-27 | 2023-05-26 |  | 88d |  |
| 99 | 4.3.2.1 | Relleno con material granular (incluye extracción de material, zarandeo y combinación | 14d | 2023-03-27 | 2023-04-09 | 93FS-4d, 64 | 88d | 0d |
| 100 | 4.3.2.2 | Relleno sin compactar | 7d | 2023-05-15 | 2023-05-21 | 109, 110 | 215d | 0d |
| 101 | 4.3.2.3 | Relleno afirmado | 5d | 2023-05-22 | 2023-05-26 | 100 | 215d | 0d |
| 102 | 4.3.2.4 | Perfilado de Talud del dique | 14d | 2023-03-28 | 2023-04-10 | 99FS-13d, 67 | 88d | 0d |
| 103 | 4.3.2.5 | Relleno con material seleccionado (incluye extracción de material, zarandeo y combinación de material) en sobreexcavación | 5d | 2023-04-10 | 2023-04-14 | 99 | 257d |  |
| 104 | 4.3.2.6 | Grava para Drenaje | 5d | 2023-05-15 | 2023-05-19 | 109, 110 | 222d | 0d |
| 105 | 4.3.3 | **Geotextil** | 35d | 2023-04-09 | 2023-05-13 |  | 88d |  |
| 106 | 4.3.3.1 | Instalación de Geotextil 400 gr/m2 | 34d | 2023-04-10 | 2023-05-13 | 107FS-33d, 71 | 215d | 0d |
| 107 | 4.3.3.2 | Zanja de anclaje | 34d | 2023-04-09 | 2023-05-12 | 102FS-2d, 72 | 88d | 0d |
| 108 | 4.3.4 | **Colocación de roca** | 34d | 2023-04-11 | 2023-05-14 |  | 215d |  |
| 109 | 4.3.4.1 | Colocación de roca en uña | 34d | 2023-04-11 | 2023-05-14 | 106FS-33d, 74 | 215d | 0d |
| 110 | 4.3.4.2 | Colocación de roca en Talud | 34d | 2023-04-11 | 2023-05-14 | 106FS-33d, 75 | 215d | 0d |
| 111 | 4.3.5 | **Transportes** | 74d | 2023-03-14 | 2023-05-26 |  | 215d |  |
| 112 | 4.3.5.1 | Transporte de material orgánico (a DMO) D<=1km | 5d | 2023-03-14 | 2023-03-18 | 91SS | 284d | 0d |
| 113 | 4.3.5.2 | Transporte de material orgánico (a DMO) D>1km | 5d | 2023-03-14 | 2023-03-18 | 91SS | 284d | 0d |
| 114 | 4.3.5.3 | Transporte de material excedente (dique provisional) D<=1km | 12d | 2023-03-19 | 2023-03-30 | 92SS, 94SS | 272d | 0d |
| 115 | 4.3.5.4 | Transporte de material excedente (dique provisional) D> 1km | 12d | 2023-03-19 | 2023-03-30 | 92SS, 94SS | 272d | 0d |
| 116 | 4.3.5.5 | Transporte de material de préstamo (afirmado) D<=1km | 5d | 2023-05-22 | 2023-05-26 | 101SS | 215d | 95d |
| 117 | 4.3.5.6 | Transporte de material de préstamo (afirmado) D>1km | 5d | 2023-05-22 | 2023-05-26 | 101SS | 215d | 95d |
| 118 | 4.3.5.7 | Transporte de roca D<=1km | 34d | 2023-04-11 | 2023-05-14 | 109SS, 110SS | 227d | 107d |
| 119 | 4.3.5.8 | Transporte de roca D>1km | 34d | 2023-04-11 | 2023-05-14 | 109SS, 110SS | 227d | 107d |
| 120 | 4.3.5.9 | Transporte de material de préstamo cantera de rio (cuerpo de terraplén) D<=1km | 14d | 2023-03-27 | 2023-04-09 | 99SS | 262d | 142d |
| 121 | 4.3.5.10 | Transporte de material de préstamo cantera de rio (cuerpo de terraplén) D>1km | 14d | 2023-03-27 | 2023-04-09 | 99SS | 262d | 142d |
| 122 | 4.3.5.11 | Transporte de material seleccionado para zanja D<=1km | 5d | 2023-05-15 | 2023-05-19 | 104SS | 222d | 102d |
| 123 | 4.3.5.12 | Transporte de material seleccionado para zanja D>1km | 5d | 2023-05-15 | 2023-05-19 | 104SS | 222d | 102d |

| ID | WBS | Task | Duration | Start | Finish | Predecessors | Total slack | Free slack |
| --- | --- | --- | --- | --- | --- | --- | --- | --- |
| 124 | 4.4 | **DIQUE DI-PR-12-I** | 174d | 2023-03-09 | 2023-08-29 |  | 28d |  |
| 125 | 4.4.1 | **Excavaciones** | 76d | 2023-03-09 | 2023-05-23 |  | 28d |  |
| 126 | 4.4.1.1 | Desbroce | 7d | 2023-03-09 | 2023-03-15 | 164 | 28d | 0d |
| 127 | 4.4.1.2 | Remoción de dique existente | 30d | 2023-03-16 | 2023-04-14 | 126 | 28d | 0d |
| 128 | 4.4.1.3 | Excavación de cimentación | 55d | 2023-03-23 | 2023-05-16 | 126, 127FS-23d | 28d | 0d |
| 129 | 4.4.1.4 | Perfilado y conformación de Plataforma de fundación | 54d | 2023-03-25 | 2023-05-17 | 128FS-53d, 130FS-53d | 28d | 0d |
| 130 | 4.4.1.5 | Excavación de uña | 55d | 2023-03-23 | 2023-05-16 | 126, 127FS-23d | 28d | 0d |
| 131 | 4.4.1.6 | Conformación de material excedente en DME | 62d | 2023-03-23 | 2023-05-23 | 151FS-62d, 152FS-62d | 218d | 98d |
| 132 | 4.4.1.7 | Conformación de material excedente en DMO | 7d | 2023-03-09 | 2023-03-15 | 149FS-7d, 150FS-7d | 287d | 167d |
| 133 | 4.4.1.8 | Excavación Localizada - Sobreexcavación | 7d | 2023-05-17 | 2023-05-23 | 128, 130 | 218d | 98d |
| 134 | 4.4.2 | **Rellenos** | 151d | 2023-04-01 | 2023-08-29 |  | 28d |  |
| 135 | 4.4.2.1 | Relleno con material granular (incluye extracción de material, zarandeo y combinación | 91d | 2023-04-01 | 2023-06-30 | 129FS-47d | 28d | 0d |
| 136 | 4.4.2.2 | Relleno sin compactar | 31d | 2023-07-15 | 2023-08-14 | 145FS-23d, 146FS-23d | 120d | 0d |
| 137 | 4.4.2.3 | Relleno afirmado | 15d | 2023-08-15 | 2023-08-29 | 136 | 120d | 0d |
| 138 | 4.4.2.4 | Perfilado de Talud del dique | 91d | 2023-04-02 | 2023-07-01 | 135FS-90d | 28d | 0d |
| 139 | 4.4.2.5 | Relleno con material seleccionado (incluye extracción de material, zarandeo y combinación de material) en sobreexcavación | 35d | 2023-07-01 | 2023-08-04 | 135 | 145d | 25d |
| 140 | 4.4.2.6 | Grava para Drenaje | 10d | 2023-07-31 | 2023-08-09 | 145FS-7d, 146FS-7d | 140d | 0d |
| 141 | 4.4.3 | **Geotextil** | 111d | 2023-04-17 | 2023-08-05 |  | 28d |  |
| 142 | 4.4.3.1 | Instalación de Geotextil 400 gr/m2 | 110d | 2023-04-18 | 2023-08-05 | 143FS-109d | 28d | 0d |
| 143 | 4.4.3.2 | Zanja de anclaje | 110d | 2023-04-17 | 2023-08-04 | 138FS-76d | 28d | 0d |
| 144 | 4.4.4 | **Colocación de roca** | 139d | 2023-03-21 | 2023-08-06 |  | 28d |  |
| 145 | 4.4.4.1 | Colocación de roca en uña | 110d | 2023-04-19 | 2023-08-06 | 142FS-109d, 147FS-31d | 28d | 0d |
| 146 | 4.4.4.2 | Colocación de roca en Talud | 110d | 2023-04-19 | 2023-08-06 | 142FS-109d, 147FS-31d | 28d | 0d |
| 147 | 4.4.4.3 | Extracción y Selección de Rocas Reutilizables (50% de roca utilizable) | 60d | 2023-03-21 | 2023-05-19 | 127FS-25d | 28d | 0d |

| ID | WBS | Task | Duration | Start | Finish | Predecessors | Total slack | Free slack |
| --- | --- | --- | --- | --- | --- | --- | --- | --- |
| 148 | 4.4.5 | **Transportes** | 174d | 2023-03-09 | 2023-08-29 |  | 120d |  |
| 149 | 4.4.5.1 | Transporte de material orgánico (a DMO) D<=1km | 7d | 2023-03-09 | 2023-03-15 | 126SS | 287d | 0d |
| 150 | 4.4.5.2 | Transporte de material orgánico (a DMO) D>1km | 7d | 2023-03-09 | 2023-03-15 | 126SS | 287d | 0d |
| 151 | 4.4.5.3 | Transporte de material excedente (dique provisional) D<=1km | 62d | 2023-03-23 | 2023-05-23 | 128SS, 130SS | 218d | 0d |
| 152 | 4.4.5.4 | Transporte de material excedente (dique provisional) D> 1km | 62d | 2023-03-23 | 2023-05-23 | 128SS, 130SS | 218d | 0d |
| 153 | 4.4.5.5 | Transporte de material de préstamo (afirmado) D<=1km | 15d | 2023-08-15 | 2023-08-29 | 137SS | 120d | 0d |
| 154 | 4.4.5.6 | Transporte de material de préstamo (afirmado) D>1km | 15d | 2023-08-15 | 2023-08-29 | 137SS | 120d | 0d |
| 155 | 4.4.5.7 | Transporte de roca D<=1km | 110d | 2023-04-19 | 2023-08-06 | 145SS, 146SS | 143d | 23d |
| 156 | 4.4.5.8 | Transporte de roca D>1km | 110d | 2023-04-19 | 2023-08-06 | 145SS, 146SS | 143d | 23d |
| 157 | 4.4.5.9 | Transporte de material de préstamo cantera de rio (cuerpo de terraplén) D<=1km | 91d | 2023-04-01 | 2023-06-30 | 135SS | 180d | 60d |
| 158 | 4.4.5.10 | Transporte de material de préstamo cantera de rio (cuerpo de terraplén) D>1km | 91d | 2023-04-01 | 2023-06-30 | 135SS | 180d | 60d |
| 159 | 4.4.5.11 | Transporte de material seleccionado para zanja D<=1km | 10d | 2023-07-31 | 2023-08-09 | 140SS | 140d | 20d |
| 160 | 4.4.5.12 | Transporte de material seleccionado para zanja D>1km | 10d | 2023-07-31 | 2023-08-09 | 140SS | 140d | 20d |
| 161 | 4.5 | **ACCESOS** | 6d | 2023-03-03 | 2023-03-08 |  | 28d |  |
| 162 | 4.5.1 | **Rellenos** | 6d | 2023-03-03 | 2023-03-08 |  | 28d |  |
| 163 | 4.5.1.1 | Relleno con material granular (incluye extracción de material, zarandeo y combinac | 4d | 2023-03-03 | 2023-03-06 | 4 | 28d | 0d |
| 164 | 4.5.1.2 | Relleno afirmado | 2d | 2023-03-07 | 2023-03-08 | 163 | 28d | 0d |
| 165 | 4.5.2 | **Transportes** | 6d | 2023-03-03 | 2023-03-08 |  | 294d |  |
| 166 | 4.5.2.1 | Transporte de material de préstamo (afirmado) D<=1km | 2d | 2023-03-07 | 2023-03-08 | 164SS | 294d | 174d |
| 167 | 4.5.2.2 | Transporte de material de préstamo (afirmado) D>1km | 2d | 2023-03-07 | 2023-03-08 | 164SS | 294d | 174d |
| 168 | 4.5.2.3 | Transporte de material de préstamo cantera de rio (cuerpo de terraplén) D<=1km | 4d | 2023-03-03 | 2023-03-06 | 163SS | 296d | 176d |
| 169 | 4.5.2.4 | Transporte de material de préstamo cantera de rio (cuerpo de terraplén) D>1km | 4d | 2023-03-03 | 2023-03-06 | 163SS | 296d | 176d |
| 170 | 4.6 | **DIQUE DI-PR-13-D** | 198d | 2023-06-13 | 2023-12-27 |  | 0d |  |
| 171 | 4.6.1 | **Excavaciones** | 101d | 2023-06-13 | 2023-09-21 |  | 0d |  |
| 172 | 4.6.1.1 | Desbroce | 10d | 2023-06-13 | 2023-06-22 | 360 | 0d |  |
| 173 | 4.6.1.2 | Excavación de cimentación | 90d | 2023-06-23 | 2023-09-20 | 172 | 0d |  |
| 174 | 4.6.1.3 | Perfilado y conformación de Plataforma de fundación | 89d | 2023-06-25 | 2023-09-21 | 173FS-88d, 175FS-88d | 0d |  |
| 175 | 4.6.1.4 | Excavación de uña | 90d | 2023-06-23 | 2023-09-20 | 172 | 0d |  |
| 176 | 4.6.1.5 | Conformación de material excedente en DME | 90d | 2023-06-23 | 2023-09-20 | 192FS-90d, 193FS-90d | 98d |  |
| 177 | 4.6.1.6 | Conformación de material excedente en DMO | 10d | 2023-06-13 | 2023-06-22 | 190FS-10d, 191FS-10d | 188d |  |

| ID | WBS | Task | Duration | Start | Finish | Predecessors | Total slack | Free slack |
| --- | --- | --- | --- | --- | --- | --- | --- | --- |
| 178 | 4.6.2 | **Rellenos** | 180d | 2023-07-01 | 2023-12-27 |  | 0d |  |
| 179 | 4.6.2.1 | Relleno con material granular (incluye extracción de material, zarandeo y combinac | 100d | 2023-07-04 | 2023-10-11 | 174FS-80d | 0d |  |
| 180 | 4.6.2.2 | Relleno sin compactar | 54d | 2023-10-20 | 2023-12-12 | 187FS-50d, 188FS-50d | 0d |  |
| 181 | 4.6.2.3 | Relleno afirmado | 15d | 2023-12-13 | 2023-12-27 | 180 | 0d |  |
| 182 | 4.6.2.4 | Perfilado de Talud del dique | 100d | 2023-07-01 | 2023-10-08 | 179FS-103d | 0d |  |
| 183 | 4.6.3 | **Geotextil** | 154d | 2023-07-07 | 2023-12-07 |  | 0d |  |
| 184 | 4.6.3.1 | Instalación de Geotextil 400 gr/m2 | 153d | 2023-07-08 | 2023-12-07 | 185FS-152d | 0d |  |
| 185 | 4.6.3.2 | Zanja de anclaje | 153d | 2023-07-07 | 2023-12-06 | 182FS-94d | 0d |  |
| 186 | 4.6.4 | **Colocación de roca** | 153d | 2023-07-09 | 2023-12-08 |  | 0d |  |
| 187 | 4.6.4.1 | Colocación de roca en uña | 153d | 2023-07-09 | 2023-12-08 | 184FS-152d | 0d |  |
| 188 | 4.6.4.2 | Colocación de roca en Talud | 153d | 2023-07-09 | 2023-12-08 | 184FS-152d | 0d |  |
| 189 | 4.6.5 | **Transportes** | 198d | 2023-06-13 | 2023-12-27 |  | 0d |  |
| 190 | 4.6.5.1 | Transporte de material orgánico (a DMO) D<=1km | 10d | 2023-06-13 | 2023-06-22 | 172SS | 188d | 0d |
| 191 | 4.6.5.2 | Transporte de material orgánico (a DMO) D>1km | 10d | 2023-06-13 | 2023-06-22 | 172SS | 188d | 0d |
| 192 | 4.6.5.3 | Transporte de material excedente (dique provisional) D<=1km | 90d | 2023-06-23 | 2023-09-20 | 173SS, 175SS | 98d | 0d |
| 193 | 4.6.5.4 | Transporte de material excedente (dique provisional) D> 1km | 90d | 2023-06-23 | 2023-09-20 | 173SS, 175SS | 98d | 0d |
| 194 | 4.6.5.5 | Transporte de material de préstamo (afirmado) D<=1km | 15d | 2023-12-13 | 2023-12-27 | 181SS | 0d |  |
| 195 | 4.6.5.6 | Transporte de material de préstamo (afirmado) D>1km | 15d | 2023-12-13 | 2023-12-27 | 181SS | 0d |  |
| 196 | 4.6.5.7 | Transporte de roca D<=1km | 153d | 2023-07-09 | 2023-12-08 | 187SS, 188SS | 19d |  |
| 197 | 4.6.5.8 | Transporte de roca D>1km | 153d | 2023-07-09 | 2023-12-08 | 187SS, 188SS | 19d |  |
| 198 | 4.6.5.9 | Transporte de material de préstamo cantera de rio (cuerpo de terraplén) D<=1km | 100d | 2023-07-04 | 2023-10-11 | 179SS | 77d |  |
| 199 | 4.6.5.10 | Transporte de material de préstamo cantera de rio (cuerpo de terraplén) D>1km | 100d | 2023-07-04 | 2023-10-11 | 179SS | 77d |  |
| 200 | 4.7 | **DIQUE DI-PR-16-D** | 89d | 2023-06-13 | 2023-09-09 |  | 88d |  |
| 201 | 4.7.1 | **Excavaciones** | 20d | 2023-06-13 | 2023-07-02 |  | 88d |  |
| 202 | 4.7.1.1 | Desbroce | 5d | 2023-06-13 | 2023-06-17 | 360 | 88d | 0d |
| 203 | 4.7.1.2 | Excavación de cimentación | 13d | 2023-06-18 | 2023-06-30 | 202 | 88d | 0d |
| 204 | 4.7.1.3 | Perfilado y conformación de Plataforma de fundación | 12d | 2023-06-20 | 2023-07-01 | 203FS-11d, 205FS-11d | 88d | 0d |
| 205 | 4.7.1.4 | Excavación de uña | 13d | 2023-06-18 | 2023-06-30 | 202 | 88d | 0d |
| 206 | 4.7.1.5 | Conformación de material excedente en DME | 13d | 2023-06-20 | 2023-07-02 | 222FS-13d, 223FS-13d | 178d |  |
| 207 | 4.7.1.6 | Conformación de material excedente en DMO | 5d | 2023-06-13 | 2023-06-17 | 220FS-5d, 221FS-5d | 193d |  |

| ID | WBS | Task | Duration | Start | Finish | Predecessors | Total slack | Free slack |
| --- | --- | --- | --- | --- | --- | --- | --- | --- |
| 208 | 4.7.2 | **Rellenos** | 70d | 2023-07-02 | 2023-09-09 |  | 88d |  |
| 209 | 4.7.2.1 | Relleno con material granular (incluye extracción de material, zarandeo y combinac | 20d | 2023-07-02 | 2023-07-21 | 204 | 88d | 0d |
| 210 | 4.7.2.2 | Relleno sin compactar | 7d | 2023-08-29 | 2023-09-04 | 217, 218 | 88d | 0d |
| 211 | 4.7.2.3 | Relleno afirmado | 5d | 2023-09-05 | 2023-09-09 | 210 | 88d | 0d |
| 212 | 4.7.2.4 | Perfilado de Talud del dique | 20d | 2023-07-03 | 2023-07-22 | 209FS-19d | 88d | 0d |
| 213 | 4.7.3 | **Geotextil** | 39d | 2023-07-20 | 2023-08-27 |  | 88d |  |
| 214 | 4.7.3.1 | Instalación de Geotextil 400 gr/m2 | 38d | 2023-07-21 | 2023-08-27 | 215FS-37d, 35 | 88d | 0d |
| 215 | 4.7.3.2 | Zanja de anclaje | 38d | 2023-07-20 | 2023-08-26 | 212FS-3d, 36 | 88d | 0d |
| 216 | 4.7.4 | **Colocación de roca** | 38d | 2023-07-22 | 2023-08-28 |  | 88d |  |
| 217 | 4.7.4.1 | Colocación de roca en uña | 38d | 2023-07-22 | 2023-08-28 | 214FS-37d, 38 | 88d | 0d |
| 218 | 4.7.4.2 | Colocación de roca en Talud | 38d | 2023-07-22 | 2023-08-28 | 214FS-37d, 39 | 88d | 0d |
| 219 | 4.7.5 | **Transportes** | 89d | 2023-06-13 | 2023-09-09 |  | 109d |  |
| 220 | 4.7.5.1 | Transporte de material orgánico (a DMO) D<=1km | 5d | 2023-06-13 | 2023-06-17 | 202SS | 193d | 0d |
| 221 | 4.7.5.2 | Transporte de material orgánico (a DMO) D>1km | 5d | 2023-06-13 | 2023-06-17 | 202SS | 193d | 0d |
| 222 | 4.7.5.3 | Transporte de material excedente (dique provisional) D<=1km | 13d | 2023-06-20 | 2023-07-02 | 203SS, 204SS | 178d | 0d |
| 223 | 4.7.5.4 | Transporte de material excedente (dique provisional) D> 1km | 13d | 2023-06-20 | 2023-07-02 | 203SS, 204SS | 178d | 0d |
| 224 | 4.7.5.5 | Transporte de material de préstamo (afirmado) D<=1km | 5d | 2023-09-05 | 2023-09-09 | 211SS | 109d |  |
| 225 | 4.7.5.6 | Transporte de material de préstamo (afirmado) D>1km | 5d | 2023-09-05 | 2023-09-09 | 211SS | 109d |  |
| 226 | 4.7.5.7 | Transporte de roca D<=1km | 38d | 2023-07-22 | 2023-08-28 | 217SS, 218SS | 121d |  |
| 227 | 4.7.5.8 | Transporte de roca D>1km | 38d | 2023-07-22 | 2023-08-28 | 217SS, 218SS | 121d |  |
| 228 | 4.7.5.9 | Transporte de material de préstamo cantera de rio (cuerpo de terraplén) D<=1km | 20d | 2023-07-02 | 2023-07-21 | 209SS | 159d |  |
| 229 | 4.7.5.10 | Transporte de material de préstamo cantera de rio (cuerpo de terraplén) D>1km | 20d | 2023-07-02 | 2023-07-21 | 209SS | 159d |  |
| 230 | 4.8 | **DIQUE DI-PR-17-D** | 105d | 2023-06-18 | 2023-09-30 |  | 88d |  |
| 231 | 4.8.1 | **Excavaciones** | 40d | 2023-06-18 | 2023-07-27 |  | 88d |  |
| 232 | 4.8.1.1 | Desbroce | 13d | 2023-06-18 | 2023-06-30 | 202 | 88d | 0d |
| 233 | 4.8.1.2 | Excavación de cimentación | 26d | 2023-07-01 | 2023-07-26 | 203, 232 | 88d | 0d |
| 234 | 4.8.1.3 | Perfilado y conformación de Plataforma de fundación | 26d | 2023-07-02 | 2023-07-27 | 233FS-25d, 235FS-25d, 204 | 88d | 0d |
| 235 | 4.8.1.4 | Excavación de uña | 26d | 2023-07-01 | 2023-07-26 | 205, 232 | 88d | 0d |
| 236 | 4.8.1.5 | Conformación de material excedente en DME | 26d | 2023-07-01 | 2023-07-26 | 252FS-26d, 253FS-26d | 154d |  |
| 237 | 4.8.1.6 | Conformación de material excedente en DMO | 13d | 2023-06-18 | 2023-06-30 | 250FS-13d, 251FS-13d | 180d |  |

| ID | WBS | Task | Duration | Start | Finish | Predecessors | Total slack | Free slack |
| --- | --- | --- | --- | --- | --- | --- | --- | --- |
| 238 | 4.8.2 | **Rellenos** | 71d | 2023-07-22 | 2023-09-30 |  | 88d |  |
| 239 | 4.8.2.1 | Relleno con material granular (incluye extracción de material, zarandeo y combinac | 35d | 2023-07-22 | 2023-08-25 | 209, 234FS-6d | 88d | 0d |
| 240 | 4.8.2.2 | Relleno sin compactar | 10d | 2023-09-14 | 2023-09-23 | 211FS+4d, 247FS-9d, 248FS-9d | 88d | 0d |
| 241 | 4.8.2.3 | Relleno afirmado | 7d | 2023-09-24 | 2023-09-30 | 240 | 88d | 0d |
| 242 | 4.8.2.4 | Perfilado de Talud del dique | 35d | 2023-07-23 | 2023-08-26 | 212, 239FS-34d | 88d | 0d |
| 243 | 4.8.3 | **Geotextil** | 26d | 2023-08-27 | 2023-09-21 |  | 88d |  |
| 244 | 4.8.3.1 | Instalación de Geotextil 400 gr/m2 | 25d | 2023-08-28 | 2023-09-21 | 245FS-24d | 88d | 0d |
| 245 | 4.8.3.2 | Zanja de anclaje | 25d | 2023-08-27 | 2023-09-20 | 215, 242 | 88d | 0d |
| 246 | 4.8.4 | **Colocación de roca** | 25d | 2023-08-29 | 2023-09-22 |  | 88d |  |
| 247 | 4.8.4.1 | Colocación de roca en uña | 25d | 2023-08-29 | 2023-09-22 | 244FS-24d | 88d | 0d |
| 248 | 4.8.4.2 | Colocación de roca en Talud | 25d | 2023-08-29 | 2023-09-22 | 244FS-24d | 88d | 0d |
| 249 | 4.8.5 | **Transportes** | 105d | 2023-06-18 | 2023-09-30 |  | 88d |  |
| 250 | 4.8.5.1 | Transporte de material orgánico (a DMO) D<=1km | 13d | 2023-06-18 | 2023-06-30 | 232SS | 180d | 0d |
| 251 | 4.8.5.2 | Transporte de material orgánico (a DMO) D>1km | 13d | 2023-06-18 | 2023-06-30 | 232SS | 180d | 0d |
| 252 | 4.8.5.3 | Transporte de material excedente (dique provisional) D<=1km | 26d | 2023-07-01 | 2023-07-26 | 233SS, 235SS | 154d | 0d |
| 253 | 4.8.5.4 | Transporte de material excedente (dique provisional) D> 1km | 26d | 2023-07-01 | 2023-07-26 | 233SS, 235SS | 154d | 0d |
| 254 | 4.8.5.5 | Transporte de material de préstamo (afirmado) D<=1km | 7d | 2023-09-24 | 2023-09-30 | 241SS | 88d |  |
| 255 | 4.8.5.6 | Transporte de material de préstamo (afirmado) D>1km | 7d | 2023-09-24 | 2023-09-30 | 241SS | 88d |  |
| 256 | 4.8.5.7 | Transporte de roca D<=1km | 25d | 2023-08-29 | 2023-09-22 | 247SS, 248SS | 96d |  |
| 257 | 4.8.5.8 | Transporte de roca D>1km | 25d | 2023-08-29 | 2023-09-22 | 247SS, 248SS | 96d |  |
| 258 | 4.8.5.9 | Transporte de material de préstamo cantera de rio (cuerpo de terraplén) D<=1km | 35d | 2023-07-22 | 2023-08-25 | 239SS | 124d |  |
| 259 | 4.8.5.10 | Transporte de material de préstamo cantera de rio (cuerpo de terraplén) D>1km | 35d | 2023-07-22 | 2023-08-25 | 239SS | 124d |  |
| 260 | 4.9 | **DIQUE DI-PR-18-D** | 170d | 2023-06-13 | 2023-11-29 |  | 28d |  |
| 261 | 4.9.1 | **Excavaciones** | 59d | 2023-06-13 | 2023-08-10 |  | 28d |  |
| 262 | 4.9.1.1 | Desbroce | 5d | 2023-06-13 | 2023-06-17 | 360 | 28d | 0d |
| 263 | 4.9.1.2 | Excavación de cimentación | 53d | 2023-06-18 | 2023-08-09 | 262 | 28d | 0d |
| 264 | 4.9.1.3 | Perfilado y conformación de Plataforma de fundación | 52d | 2023-06-20 | 2023-08-10 | 263FS-51d, 265FS-51d | 28d | 0d |
| 265 | 4.9.1.4 | Excavación de uña | 53d | 2023-06-18 | 2023-08-09 | 262 | 28d | 0d |
| 266 | 4.9.1.5 | Conformación de material excedente en DME | 53d | 2023-06-18 | 2023-08-09 | 282FS-53d, 283FS-53d | 140d |  |
| 267 | 4.9.1.6 | Conformación de material excedente en DMO | 5d | 2023-06-13 | 2023-06-17 | 280FS-5d, 281FS-5d | 193d |  |

| ID | WBS | Task | Duration | Start | Finish | Predecessors | Total slack | Free slack |
| --- | --- | --- | --- | --- | --- | --- | --- | --- |
| 268 | 4.9.2 | **Rellenos** | 125d | 2023-07-28 | 2023-11-29 |  | 28d |  |
| 269 | 4.9.2.1 | Relleno con material granular (incluye extracción de material, zarandeo y combinac | 62d | 2023-07-28 | 2023-09-27 | 264FS-14d | 28d | 0d |
| 270 | 4.9.2.2 | Relleno sin compactar | 19d | 2023-11-04 | 2023-11-22 | 277, 278 | 28d | 0d |
| 271 | 4.9.2.3 | Relleno afirmado | 7d | 2023-11-23 | 2023-11-29 | 270 | 28d | 0d |
| 272 | 4.9.2.4 | Perfilado de Talud del dique | 62d | 2023-07-29 | 2023-09-28 | 269FS-61d | 28d | 0d |
| 273 | 4.9.3 | **Geotextil** | 90d | 2023-08-05 | 2023-11-02 |  | 28d |  |
| 274 | 4.9.3.1 | Instalación de Geotextil 400 gr/m2 | 89d | 2023-08-06 | 2023-11-02 | 275FS-88d, 142 | 28d | 0d |
| 275 | 4.9.3.2 | Zanja de anclaje | 89d | 2023-08-05 | 2023-11-01 | 272FS-55d, 143 | 28d | 0d |
| 276 | 4.9.4 | **Colocación de roca** | 89d | 2023-08-07 | 2023-11-03 |  | 28d |  |
| 277 | 4.9.4.1 | Colocación de roca en uña | 89d | 2023-08-07 | 2023-11-03 | 274FS-88d, 145 | 28d | 0d |
| 278 | 4.9.4.2 | Colocación de roca en Talud | 89d | 2023-08-07 | 2023-11-03 | 274FS-88d, 146 | 28d | 0d |
| 279 | 4.9.5 | **Transportes** | 170d | 2023-06-13 | 2023-11-29 |  | 28d |  |
| 280 | 4.9.5.1 | Transporte de material orgánico (a DMO) D<=1km | 5d | 2023-06-13 | 2023-06-17 | 262SS | 193d | 0d |
| 281 | 4.9.5.2 | Transporte de material orgánico (a DMO) D>1km | 5d | 2023-06-13 | 2023-06-17 | 262SS | 193d | 0d |
| 282 | 4.9.5.3 | Transporte de material excedente (dique provisional) D<=1km | 53d | 2023-06-18 | 2023-08-09 | 263SS, 265SS | 140d | 0d |
| 283 | 4.9.5.4 | Transporte de material excedente (dique provisional) D> 1km | 53d | 2023-06-18 | 2023-08-09 | 263SS, 265SS | 140d | 0d |
| 284 | 4.9.5.5 | Transporte de material de préstamo (afirmado) D<=1km | 7d | 2023-11-23 | 2023-11-29 | 271SS | 28d |  |
| 285 | 4.9.5.6 | Transporte de material de préstamo (afirmado) D>1km | 7d | 2023-11-23 | 2023-11-29 | 271SS | 28d |  |
| 286 | 4.9.5.7 | Transporte de roca D<=1km | 89d | 2023-08-07 | 2023-11-03 | 277SS, 278SS | 54d |  |
| 287 | 4.9.5.8 | Transporte de roca D>1km | 89d | 2023-08-07 | 2023-11-03 | 277SS, 278SS | 54d |  |
| 288 | 4.9.5.9 | Transporte de material de préstamo cantera de rio (cuerpo de terraplén) D<=1km | 62d | 2023-07-28 | 2023-09-27 | 269SS | 91d |  |
| 289 | 4.9.5.10 | Transporte de material de préstamo cantera de rio (cuerpo de terraplén) D>1km | 62d | 2023-07-28 | 2023-09-27 | 269SS | 91d |  |
| 290 | 4.10 | **DIQUE DI-PR-19A-D** | 191d | 2023-06-20 | 2023-12-27 |  | 0d |  |
| 291 | 4.10.1 | **Excavaciones** | 85d | 2023-06-20 | 2023-09-12 |  | 0d |  |
| 292 | 4.10.1.1 | Desbroce | 15d | 2023-06-20 | 2023-07-04 | 324 | 0d |  |
| 293 | 4.10.1.2 | Excavación de cimentación | 62d | 2023-07-05 | 2023-09-04 | 292 | 0d |  |
| 294 | 4.10.1.3 | Perfilado y conformación de Plataforma de fundación | 68d | 2023-07-07 | 2023-09-12 | 293FS-60d, 295FS-60d | 0d |  |
| 295 | 4.10.1.4 | Excavación de uña | 62d | 2023-07-05 | 2023-09-04 | 292 | 0d |  |
| 296 | 4.10.1.5 | Conformación de material excedente en DME | 62d | 2023-07-05 | 2023-09-04 | 314FS-62d, 315FS-62d | 114d |  |
| 297 | 4.10.1.6 | Conformación de material excedente en DMO | 19d | 2023-06-20 | 2023-07-08 | 312FS-15d, 313FS-15d | 172d |  |
| 298 | 4.10.1.7 | Excavación Localizada - Sobreexcavación | 7d | 2023-09-05 | 2023-09-11 | 293, 295 | 107d |  |

| ID | WBS | Task | Duration | Start | Finish | Predecessors | Total slack | Free slack |
| --- | --- | --- | --- | --- | --- | --- | --- | --- |
| 299 | 4.10.2 | **Rellenos** | 167d | 2023-07-14 | 2023-12-27 |  | 0d |  |
| 300 | 4.10.2.1 | Relleno con material granular (incluye extracción de material, zarandeo y combinac | 80d | 2023-07-14 | 2023-10-01 | 294FS-61d | 0d |  |
| 301 | 4.10.2.2 | Relleno sin compactar | 38d | 2023-11-04 | 2023-12-11 | 309FS-24d, 310FS-24d | 0d |  |
| 302 | 4.10.2.3 | Relleno afirmado | 16d | 2023-12-12 | 2023-12-27 | 301 | 0d |  |
| 303 | 4.10.2.4 | Perfilado de Talud del dique | 80d | 2023-07-15 | 2023-10-02 | 300FS-79d | 0d |  |
| 304 | 4.10.2.5 | Relleno con material seleccionado (incluye extracción de material, zarandeo y combinación de material) en sobreexcavación | 37d | 2023-11-04 | 2023-12-10 | 309FS-24d, 310FS-24d | 17d |  |
| 305 | 4.10.3 | **Geotextil** | 128d | 2023-07-22 | 2023-11-26 |  | 0d |  |
| 306 | 4.10.3.1 | Instalación de Geotextil 400 gr/m2 | 127d | 2023-07-23 | 2023-11-26 | 307FS-126d | 0d |  |
| 307 | 4.10.3.2 | Zanja de anclaje | 127d | 2023-07-22 | 2023-11-25 | 303FS-73d | 0d |  |
| 308 | 4.10.4 | **Colocación de roca** | 127d | 2023-07-24 | 2023-11-27 |  | 0d |  |
| 309 | 4.10.4.1 | Colocación de roca en uña | 127d | 2023-07-24 | 2023-11-27 | 306FS-126d | 0d |  |
| 310 | 4.10.4.2 | Colocación de roca en Talud | 127d | 2023-07-24 | 2023-11-27 | 306FS-126d | 0d |  |
| 311 | 4.10.5 | **Transportes** | 191d | 2023-06-20 | 2023-12-27 |  | 0d |  |
| 312 | 4.10.5.1 | Transporte de material orgánico (a DMO) D<=1km | 15d | 2023-06-20 | 2023-07-04 | 292SS | 172d | 0d |
| 313 | 4.10.5.2 | Transporte de material orgánico (a DMO) D>1km | 15d | 2023-06-20 | 2023-07-04 | 292SS | 172d | 0d |
| 314 | 4.10.5.3 | Transporte de material excedente (dique provisional) D<=1km | 62d | 2023-07-05 | 2023-09-04 | 293SS, 295SS | 114d | 0d |
| 315 | 4.10.5.4 | Transporte de material excedente (dique provisional) D> 1km | 62d | 2023-07-05 | 2023-09-04 | 293SS, 295SS | 114d | 0d |
| 316 | 4.10.5.5 | Transporte de material de préstamo (afirmado) D<=1km | 16d | 2023-12-12 | 2023-12-27 | 302SS | 0d |  |
| 317 | 4.10.5.6 | Transporte de material de préstamo (afirmado) D>1km | 16d | 2023-12-12 | 2023-12-27 | 302SS | 0d |  |
| 318 | 4.10.5.7 | Transporte de roca D<=1km | 127d | 2023-07-24 | 2023-11-27 | 309SS, 310SS | 30d |  |
| 319 | 4.10.5.8 | Transporte de roca D>1km | 127d | 2023-07-24 | 2023-11-27 | 309SS, 310SS | 30d |  |
| 320 | 4.10.5.9 | Transporte de material de préstamo cantera de rio (cuerpo de terraplén) D<=1km | 80d | 2023-07-14 | 2023-10-01 | 300SS | 87d |  |
| 321 | 4.10.5.10 | Transporte de material de préstamo cantera de rio (cuerpo de terraplén) D>1km | 80d | 2023-07-14 | 2023-10-01 | 300SS | 87d |  |
| 322 | 4.11 | **DIQUE DI-PR-19B-D** | 198d | 2023-06-13 | 2023-12-27 |  | 0d |  |
| 323 | 4.11.1 | **Excavaciones** | 64d | 2023-06-13 | 2023-08-15 |  | 0d |  |
| 324 | 4.11.1.1 | Desbroce | 7d | 2023-06-13 | 2023-06-19 | 360 | 0d |  |
| 325 | 4.11.1.2 | Excavación de cimentación | 56d | 2023-06-20 | 2023-08-14 | 324 | 0d |  |
| 326 | 4.11.1.3 | Perfilado y conformación de Plataforma de fundación | 55d | 2023-06-22 | 2023-08-15 | 325FS-54d, 327FS-54d | 0d |  |
| 327 | 4.11.1.4 | Excavación de uña | 56d | 2023-06-20 | 2023-08-14 | 324 | 0d |  |
| 328 | 4.11.1.5 | Conformación de material excedente en DME | 56d | 2023-06-20 | 2023-08-14 | 344FS-56d, 345FS-56d | 135d |  |
| 329 | 4.11.1.6 | Conformación de material excedente en DMO | 7d | 2023-06-13 | 2023-06-19 | 342FS-7d, 343FS-7d | 191d |  |

| ID | WBS | Task | Duration | Start | Finish | Predecessors | Total slack | Free slack |
| --- | --- | --- | --- | --- | --- | --- | --- | --- |
| 330 | 4.11.2 | **Rellenos** | 179d | 2023-07-02 | 2023-12-27 |  | 0d |  |
| 331 | 4.11.2.1 | Relleno con material granular (incluye extracción de material, zarandeo y combinac | 49d | 2023-07-02 | 2023-08-19 | 326FS-45d | 0d |  |
| 332 | 4.11.2.2 | Relleno sin compactar | 23d | 2023-11-28 | 2023-12-20 | 339FS-21d, 340FS-21d | 0d |  |
| 333 | 4.11.2.3 | Relleno afirmado | 7d | 2023-12-21 | 2023-12-27 | 332 | 0d |  |
| 334 | 4.11.2.4 | Perfilado de Talud del dique | 49d | 2023-07-03 | 2023-08-20 | 331FS-48d | 0d |  |
| 335 | 4.11.3 | **Geotextil** | 161d | 2023-07-10 | 2023-12-17 |  | 0d |  |
| 336 | 4.11.3.1 | Instalación de Geotextil 400 gr/m2 | 160d | 2023-07-11 | 2023-12-17 | 337FS-159d | 0d |  |
| 337 | 4.11.3.2 | Zanja de anclaje | 160d | 2023-07-10 | 2023-12-16 | 334FS-42d | 0d |  |
| 338 | 4.11.4 | **Colocación de roca** | 160d | 2023-07-12 | 2023-12-18 |  | 0d |  |
| 339 | 4.11.4.1 | Colocación de roca en uña | 160d | 2023-07-12 | 2023-12-18 | 336FS-159d | 0d |  |
| 340 | 4.11.4.2 | Colocación de roca en Talud | 160d | 2023-07-12 | 2023-12-18 | 336FS-159d | 0d |  |
| 341 | 4.11.5 | **Transportes** | 198d | 2023-06-13 | 2023-12-27 |  | 0d |  |
| 342 | 4.11.5.1 | Transporte de material orgánico (a DMO) D<=1km | 7d | 2023-06-13 | 2023-06-19 | 324SS | 191d | 0d |
| 343 | 4.11.5.2 | Transporte de material orgánico (a DMO) D>1km | 7d | 2023-06-13 | 2023-06-19 | 324SS | 191d | 0d |
| 344 | 4.11.5.3 | Transporte de material excedente (dique provisional) D<=1km | 56d | 2023-06-20 | 2023-08-14 | 325SS, 327SS | 135d | 0d |
| 345 | 4.11.5.4 | Transporte de material excedente (dique provisional) D> 1km | 56d | 2023-06-20 | 2023-08-14 | 325SS, 327SS | 135d | 0d |
| 346 | 4.11.5.5 | Transporte de material de préstamo (afirmado) D<=1km | 7d | 2023-12-21 | 2023-12-27 | 333SS | 0d |  |
| 347 | 4.11.5.6 | Transporte de material de préstamo (afirmado) D>1km | 7d | 2023-12-21 | 2023-12-27 | 333SS | 0d |  |
| 348 | 4.11.5.7 | Transporte de roca D<=1km | 160d | 2023-07-12 | 2023-12-18 | 339SS, 340SS | 9d |  |
| 349 | 4.11.5.8 | Transporte de roca D>1km | 160d | 2023-07-12 | 2023-12-18 | 339SS, 340SS | 9d |  |
| 350 | 4.11.5.9 | Transporte de material de préstamo cantera de rio (cuerpo de terraplén) D<=1km | 49d | 2023-07-02 | 2023-08-19 | 331SS | 130d |  |
| 351 | 4.11.5.10 | Transporte de material de préstamo cantera de rio (cuerpo de terraplén) D>1km | 49d | 2023-07-02 | 2023-08-19 | 331SS | 130d |  |
| 352 | 4.12 | **ACCESOS** | 27d | 2023-05-17 | 2023-06-12 |  | 0d |  |
| 353 | 4.12.1 | **Excavaciones** | 10d | 2023-05-17 | 2023-05-26 |  | 0d |  |
| 354 | 4.12.1.1 | Desbroce | 5d | 2023-05-17 | 2023-05-21 | 6 | 0d |  |
| 355 | 4.12.1.2 | Excavación de cimentación | 5d | 2023-05-22 | 2023-05-26 | 354 | 0d |  |
| 356 | 4.12.1.3 | Conformación de material excedente en DME | 5d | 2023-05-22 | 2023-05-26 | 364FS-5d, 365FS-5d | 215d |  |
| 357 | 4.12.1.4 | Conformación de material excedente en DMO | 5d | 2023-05-17 | 2023-05-21 | 362FS-5d, 363FS-5d | 220d |  |

| ID | WBS | Task | Duration | Start | Finish | Predecessors | Total slack | Free slack |
| --- | --- | --- | --- | --- | --- | --- | --- | --- |
| 358 | 4.12.2 | **Rellenos** | 17d | 2023-05-27 | 2023-06-12 |  | 0d |  |
| 359 | 4.12.2.1 | Relleno con material granular (incluye extracción de material, zarandeo y combinac | 10d | 2023-05-27 | 2023-06-05 | 355 | 0d |  |
| 360 | 4.12.2.2 | Relleno afirmado | 7d | 2023-06-06 | 2023-06-12 | 359 | 0d |  |
| 361 | 4.12.3 | **Transportes** | 27d | 2023-05-17 | 2023-06-12 |  | 198d |  |
| 362 | 4.12.3.1 | Transporte de material orgánico (a DMO) D<=1km | 5d | 2023-05-17 | 2023-05-21 | 354SS | 220d | 0d |
| 363 | 4.12.3.2 | Transporte de material orgánico (a DMO) D>1km | 5d | 2023-05-17 | 2023-05-21 | 354SS | 220d | 0d |
| 364 | 4.12.3.3 | Transporte de material excedente (dique provisional) D<=1km | 5d | 2023-05-22 | 2023-05-26 | 355SS | 215d | 0d |
| 365 | 4.12.3.4 | Transporte de material excedente (dique provisional) D> 1km | 5d | 2023-05-22 | 2023-05-26 | 355SS | 215d | 0d |
| 366 | 4.12.3.5 | Transporte de material de préstamo (afirmado) D<=1km | 7d | 2023-06-06 | 2023-06-12 | 360SS | 198d |  |
| 367 | 4.12.3.6 | Transporte de material de préstamo (afirmado) D>1km | 7d | 2023-06-06 | 2023-06-12 | 360SS | 198d |  |
| 368 | 4.12.3.7 | Transporte de material de préstamo cantera de rio (cuerpo de terraplén) D<=1km | 10d | 2023-05-27 | 2023-06-05 | 359SS | 205d |  |
| 369 | 4.12.3.8 | Transporte de material de préstamo cantera de rio (cuerpo de terraplén) D>1km | 10d | 2023-05-27 | 2023-06-05 | 359SS | 205d |  |
| 370 | 5 | **OBRAS CIVILES** | 330d | 2023-02-01 | 2023-12-27 |  | 0d |  |
| 371 | 5.1 | Trazo y replanteo de interferencia | 330d | 2023-02-01 | 2023-12-27 | 2 | 0d |  |
| 372 | 5.2 | Desvío provisional con tubería | 41d | 2023-02-01 | 2023-03-13 | 374FS-13d | 0d |  |
| 373 | 5.3 | Desvío provisional en tierras | 86d | 2023-03-14 | 2023-06-07 | 372 | 0d |  |
| 374 | 5.4 | Limpieza de terreno manual | 13d | 2023-02-01 | 2023-02-13 | 2, 371SS | 0d |  |
| 375 | 5.5 | Excavaciones no clasificada para estructuras | 34d | 2023-03-29 | 2023-05-01 | 373FS-71d | 0d |  |
| 376 | 5.6 | Excavacion no clasificada de zanja | 156d | 2023-05-02 | 2023-10-04 | 375 | 0d |  |
| 377 | 5.7 | Relleno estructural | 76d | 2023-07-27 | 2023-10-10 | 376FS-70d | 0d |  |
| 378 | 5.8 | Suministro de roca (Alcantarillas) | 33d | 2023-10-11 | 2023-11-12 | 377 | 26d | 0d |
| 379 | 5.9 | Colocación de roca en uña (Alcantarillas) | 19d | 2023-11-13 | 2023-12-01 | 378 | 26d |  |
| 380 | 5.10 | Concreto de Nivelacion (f'c=100 kg/cm2) | 10d | 2023-10-11 | 2023-10-20 | 377 | 0d |  |
| 381 | 5.11 | Concreto Clase F (f'c=140 kg/cm2) | 19d | 2023-10-21 | 2023-11-08 | 380 | 0d |  |
| 382 | 5.12 | Concreto Clase C (f'c=280 kg/cm2) Premezclado - Cimientos reforzados | 7d | 2023-11-09 | 2023-11-15 | 381 | 0d |  |
| 383 | 5.13 | Concreto Clase C (f'c=280 kg/cm2) Premezclado - Muros de contencion | 30d | 2023-11-16 | 2023-12-15 | 382 | 0d |  |
| 384 | 5.14 | Encofrado y Desencofrado Caravista | 39d | 2023-09-11 | 2023-10-19 | 377FS-30d | 5d | 0d |
| 385 | 5.15 | Encofrado y Desencofrado Cara Oculta | 51d | 2023-10-20 | 2023-12-09 | 384 | 5d | 0d |
| 386 | 5.16 | Acero de refuerzo f'y=4200kg/cm2 | 90d | 2023-09-11 | 2023-12-09 | 377FS-30d | 18d |  |
| 387 | 5.17 | Emboquillado de piedra e=0.20m | 23d | 2023-10-27 | 2023-11-18 | 383FS-50d | 0d |  |
| 388 | 5.18 | Emboquillado de piedra e=0.30m | 27d | 2023-11-19 | 2023-12-15 | 387 | 0d |  |
| 389 | 5.19 | Emboquillado de piedra e=0.50m | 12d | 2023-12-16 | 2023-12-27 | 388 | 0d |  |
| 390 | 5.20 | Cama de arena e=0.20m | 21d | 2023-10-11 | 2023-10-31 | 377 | 0d |  |
| 391 | 5.21 | Tubería HDPE Corrugada Ø=900mm (Suministro e instalación) | 4d | 2023-11-01 | 2023-11-04 | 390 | 0d |  |
| 392 | 5.22 | Tubería HDPE Corrugada Ø=1200mm (Suministro e instalación) | 7d | 2023-11-05 | 2023-11-11 | 391 | 0d |  |
| 393 | 5.23 | Compuertas Charnela Ø900 (Suministro e instalacion) | 12d | 2023-11-12 | 2023-11-23 | 392 | 0d |  |
| 394 | 5.24 | Compuertas Charnela Ø1200 (Suministro e instalacion) | 17d | 2023-11-24 | 2023-12-10 | 393 | 0d |  |
| 395 | 5.25 | Compuerta metálica tipo tarjeta 1.00x1.00m (Suministro e instalacion) | 9d | 2023-12-11 | 2023-12-19 | 394 | 0d |  |
| 396 | 5.26 | Sello en juntas | 2d | 2023-12-20 | 2023-12-21 | 395 | 0d |  |
| 397 | 5.27 | Waterstop (anillos de estanqueidad) | 3d | 2023-12-22 | 2023-12-24 | 396 | 0d |  |
| 398 | 5.28 | Pintura bituminosa | 2d | 2023-12-25 | 2023-12-26 | 397 | 0d |  |
| 399 | 5.29 | Relleno con material granular (incluye extracción de material, zarandeo y combinac | 1d | 2023-12-27 | 2023-12-27 | 398 | 0d |  |

| ID | WBS | Task | Type | Duration | Start | Finish | Predecessors | Total slack |
| --- | --- | --- | --- | --- | --- | --- | --- | --- |
| 400 | 6 | **ACCESOS** |  | 18d | 2023-12-10 | 2023-12-27 |  | 0d |
| 401 | 6.1 | **Superficie de rodadura** |  | 18d | 2023-12-10 | 2023-12-27 |  | 0d |
| 402 | 6.1.1 | Concreto clase C (f'c=280 kg/cm2) en losa |  | 3d | 2023-12-24 | 2023-12-26 | 405 | 0d |
| 403 | 6.1.2 | Encofrado y desencofrado pavimento rígido e=0.15m |  | 13d | 2023-12-10 | 2023-12-22 | 385 | 5d |
| 404 | 6.1.3 | Junta en Pavimentos con Pasadores |  | 1d | 2023-12-27 | 2023-12-27 | 402 | 0d |
| 405 | 6.1.4 | Concreto Ciclopeo f'c=210 kg/cm2 + 30% PM |  | 8d | 2023-12-16 | 2023-12-23 | 383 | 0d |
| 406 | 7 | Fin | milestone | 0d | 2023-12-27 | 2023-12-27 | 9, 10, 13, 17, 6, 7, 379, 386, 389, 399, 403, 404 | 0d |
